# A2 TRAMO I - LACRAMARCA.REV.02

Schedule from Primavera P6, 2023-11-06 to 2025-02-15, data date 2023-11-05.

## Calendars

- LACRAMARCA EFECTIVOS: Mon-Sat 08:00-16:30; Sun off. Exceptions (off unless hours are given): 2023-12-08 to 2023-12-09, 2023-12-25, 2024-01-01, 2024-03-28 to 2024-03-29, 2024-04-06 08:00-16:00, 2024-05-01, 2024-06-29, 2024-07-29, 2024-08-30, 2024-10-08, 2024-11-01, 2024-12-25, 2025-01-01.
- DÍAS CALENDARIOS: Mon-Sun 08:00-16:00.

## Resources

| Resource | Group | Notes |
| --- | --- | --- |
| Camión grua | labor | ï»¿ |
| CAPATAZ | labor | ï»¿ |
| OPERARIO | labor | ï»¿ |
| PEON | labor | ï»¿ |
| Camión Cisterna 4x2 400 HP Agua (5000 gal) | labor | ï»¿ |
| CUADRADOR/VIGÍA | labor | ï»¿ |
| Motoniveladora 185 HP | labor | ï»¿ |
| Retroexcavador 58 HP | labor | ï»¿ |
| Rodillo Vib. Liso Autopropulsado 135 HP 12 TM | labor | ï»¿ |
| Excavadora Sobre Oruga 260 HP | labor | ï»¿ |
| Tractor S/Orugas (D6T) - 180 HP | labor | ï»¿ |
| OFICIAL | labor | ï»¿ |
| Camión Volquete (15 m3) | labor | ï»¿ |
| CARGADOR SOBRE LLANTAS DE 200-250 HP | labor | ï»¿ |
| Excavadora Sobre Oruga 320 | labor | ï»¿ |
| AYUDANTE DE NIVELADOR | labor | ï»¿ |
| AYUDANTE DE TOPOGRAFO | labor | ï»¿ |
| TOPOGRAFO | labor | ï»¿ |
| OP. NIVELADOR | labor | ï»¿ |
| Camión baranda 3 TON | labor | ï»¿ |
| Excavadora + Martillo hidraúlico | labor | ï»¿ |

## Schedule

| ID | WBS | Activity | Type | Duration | Start | Finish | Predecessors | Total float | Free float | Calendar | Resources |
| --- | --- | --- | --- | --- | --- | --- | --- | --- | --- | --- | --- |
|  | 1 | **HITOS** |  |  | 2023-11-06 | 2023-11-09 |  |  |  |  |  |
| A1010 |  | BUENA PRO | milestone | 0d | 2023-11-06 | 2023-11-06 |  | 0d |  | DÍAS CALENDARIOS |  |
| A1020 |  | KICK OF MEETING (KMO) | milestone | 0d | 2023-11-09 | 2023-11-09 | A1010 SS+3.9d | 0d |  | DÍAS CALENDARIOS |  |
|  | 2 | **INICIO DE PLAZO CONTRACTUAL - FIN DE OBRA** |  |  | 2023-11-24 | 2025-02-15 |  |  |  |  |  |
| A1030 |  | INICIO DEL PLAZO CONTRACTUAL - ACCESO AL SITIO | milestone | 0d | 2023-11-24 | 2023-11-24 | A1020 SS+14.5d | 0d |  | DÍAS CALENDARIOS |  |
| A1070 |  | INICIO DE DIQUE MARGEN IZQUIERDA | milestone | 0d | 2023-11-28 | 2023-11-28 | 1.07.100 SS | 445.96d |  | DÍAS CALENDARIOS |  |
| A1040 |  | INICIO DE EXCAVACIÓN | milestone | 0d | 2023-11-28 | 2023-11-28 | A1030 SS+4.4d | 44.65d | 0d | DÍAS CALENDARIOS |  |
| A1050 |  | INICIO DE RELLENO DE DIQUE | milestone | 0d | 2023-12-04 | 2023-12-04 | A1040 SS+5.5d | 57.75d | 0.23d | DÍAS CALENDARIOS |  |
| A1110 |  | INICIO DE DIQUE MARGEN DERECHA | milestone | 0d | 2023-12-27 | 2023-12-27 | 1.07.500 SS | 416.96d |  | DÍAS CALENDARIOS |  |
| A1130 |  | INICIO DE DIQUE INTERFERENCIAS | milestone | 0d | 2024-03-11 | 2024-03-11 | 1.07.710 SS | 341.96d |  | DÍAS CALENDARIOS |  |
| A1150 |  | INICIO DE DIQUE LIBERACIÓN PREDIAL | milestone | 0d | 2024-04-11 | 2024-04-11 | 1.07.730 SS | 310.9d |  | DÍAS CALENDARIOS |  |
| A1230 |  | FIN DE DIQUE INTERFERENCIAS | milestone | 0d | 2024-06-06 | 2024-06-06 | 1.07.810 FF | 254.37d |  | DÍAS CALENDARIOS |  |
| A1260 |  | FIN DE DIQUE LIBERACIÓN PREDIAL | milestone | 0d | 2024-11-23 | 2024-11-23 | 1.07.840 FF | 84.9d |  | DÍAS CALENDARIOS |  |
| A1210 |  | FIN DE DIQUE MARGEN DERECHA | milestone | 0d | 2025-01-20 | 2025-01-20 | 1.07.235 FF | 26.37d |  | DÍAS CALENDARIOS |  |
| A1200 |  | FIN DE DIQUE MARGEN IZQUIERDA | milestone | 0d | 2025-01-21 | 2025-01-21 | 1.07.234 FF | 25.12d |  | DÍAS CALENDARIOS |  |
| A1270 |  | FIN DE OBRA | milestone | 0d | 2025-02-15 | 2025-02-15 | 01.10.03 FF+0.3d | 0d |  | DÍAS CALENDARIOS |  |
|  | 3 | **CONSTRUCCIÓN SUB PROYECTO A2 TRAMO I-RÍO LACRAMARCA** |  |  | 2023-11-24 | 2025-02-15 |  |  |  |  |  |
|  | 1 | **SUBPROYECTO A2 TRAMO I (OPCIÓN A)** |  |  | 2023-11-24 | 2025-02-08 |  |  |  |  |  |
|  | 1 | **DEFENSAS RIBEREÑAS** |  |  | 2023-11-24 | 2025-02-08 |  |  |  |  |  |
|  | 1 | **OBRAS PRELIMINARES** |  |  | 2023-11-28 | 2025-02-05 |  |  |  |  |  |
| 1.01.02 |  | INSTALACIONES PROVISIONALES PARA LA OBRA |  | 0.5d | 2023-11-28 | 2023-11-28 | 01.02.01 FS-10.4d | 8.68d | 0d |  | Camión grua [216 h]; CAPATAZ [80 h]; OPERARIO [480 h]; PEON [800 h] |
| 1.01.03 |  | MANTENIMIENTO DE TRÁNSITO Y SEGURIDAD VIAL |  | 359.5d | 2023-11-28 | 2025-02-05 | 1.01.02 SS | 8.68d |  |  | Camión Cisterna 4x2 400 HP Agua (5000 gal) [4680 h]; CAPATAZ [3120 h]; CUADRADOR/VIGÍA [6240 h]; Motoniveladora 185 HP [2340 h]; Retroexcavador 58 HP [1170 h]; Rodillo Vib. Liso Autopropulsado 135 HP 12 TM [2340 h] |
|  | 2 | **TRABAJOS PRELIMINARES** |  |  | 2023-11-24 | 2025-02-08 |  |  |  |  |  |
| 01.02.01 |  | MOVILIZACIÓN DE EQUIPOS |  | 13.76d | 2023-11-24 | 2023-12-12 | A1030 SS-0.4d | 0d |  |  | AYUDANTE DE NIVELADOR [9485 h]; AYUDANTE DE TOPOGRAFO [9485 h]; TOPOGRAFO [6323.2 h]; OP. NIVELADOR [3161.6 h] |
| 01.02.02 |  | TOPOGRAFÍA Y GEOREFERENCIACIÓN |  | 362.5d | 2023-11-28 | 2025-02-08 | A1030 SS+4d | 5.67d |  |  | AYUDANTE DE NIVELADOR [9485 h]; AYUDANTE DE TOPOGRAFO [9485 h]; TOPOGRAFO [6323.2 h]; OP. NIVELADOR [3161.6 h] |

| ID | WBS | Activity | Duration | Start | Finish | Predecessors | Total float | Free float | Resources |
| --- | --- | --- | --- | --- | --- | --- | --- | --- | --- |
|  | 3 | **DIQUES DE TIERRA COMPACTADA CON ENROCADO** |  | 2023-12-12 | 2024-11-11 |  |  |  |  |
|  | 1 | **COLOCACION Y ACOMODO DE ROCA EN UÑA DE DIQUE** |  | 2023-12-12 | 2024-11-11 |  |  |  |  |
| 1.03.612 |  | COLOCACION Y ACOMODO DE ROCA EN UÑA DE DIQUE A2-I-01-B | 3.5d | 2023-12-12 | 2023-12-15 | 1.07.622 FS+0.5d | 45.55d | 0d | CAPATAZ [113.47 h]; OPERARIO [113.47 h]; PEON [567.73 h]; Excavadora Sobre Oruga 260 HP [170.3 h] |
| 1.03.613 |  | COLOCACION Y ACOMODO DE ROCA EN UÑA DE DIQUE A2-I-03 | 3.5d | 2024-01-08 | 2024-01-11 | 1.07.623 FS+0.5d | 324.05d | 0d | CAPATAZ [255.11 h]; OPERARIO [255.11 h]; PEON [1276.37 h]; Excavadora Sobre Oruga 260 HP [382.87 h] |
| 1.03.611 |  | COLOCACION Y ACOMODO DE ROCA EN UÑA DE DIQUE A2-I-01 | 4.5d | 2024-01-23 | 2024-01-27 | 1.07.621 FS+0.5d | 314.05d | 0d | CAPATAZ [176.61 h]; OPERARIO [176.61 h]; PEON [883.61 h]; Excavadora Sobre Oruga 260 HP [265.05 h] |
| 1.03.617 |  | COLOCACION Y ACOMODO DE ROCA EN UÑA DE DIQUE A2-D-02 | 2.5d | 2024-03-20 | 2024-03-22 | 1.07.626 FS+0.5d | 264.05d | 0d | CAPATAZ [259.47 h]; OPERARIO [259.47 h]; PEON [1298.19 h]; Excavadora Sobre Oruga 260 HP [389.41 h] |
| 1.03.618 |  | COLOCACION Y ACOMODO DE ROCA EN UÑA DE DIQUE INTERFERENCIA SEDACHIMBOTE | 11.5d | 2024-05-07 | 2024-05-20 | 1.07.627 FS+0.5d | 211.05d | 0d | CAPATAZ [30.04 h]; PEON [300.43 h]; Tractor S/Orugas (D6T) - 180 HP [300.43 h]; Excavadora Sobre Oruga 260 HP [300.43 h] |
| 1.03.619 |  | COLOCACION Y ACOMODO DE ROCA EN UÑA DE DIQUE INTERFERENCIA QUAVI | 5.5d | 2024-05-11 | 2024-05-17 | 1.07.628 FS+0.5d | 220.05d | 0d | CAPATAZ [223.6 h]; PEON [2235.97 h]; Tractor S/Orugas (D6T) - 180 HP [2235.97 h]; Excavadora Sobre Oruga 260 HP [2235.97 h] |
| 1.03.620 |  | COLOCACION Y ACOMODO DE ROCA EN UÑA DE DIQUE LIBERACIÓN PREDIAL LI | 5.5d | 2024-05-20 | 2024-05-25 | 1.07.629 FS+0.5d | 206.05d | 0d | CAPATAZ [30.04 h]; PEON [300.43 h]; Tractor S/Orugas (D6T) - 180 HP [300.43 h]; Excavadora Sobre Oruga 260 HP [300.43 h] |
| 1.03.614 |  | COLOCACION Y ACOMODO DE ROCA EN UÑA DE DIQUE A2-I-02 | 63.5d | 2024-07-26 | 2024-10-11 | 1.07.624 FS+0.5d | 0d |  | CAPATAZ [2281.92 h]; OPERARIO [2281.92 h]; PEON [11417 h]; Excavadora Sobre Oruga 260 HP [3424.74 h] |
| 1.03.621 |  | COLOCACION Y ACOMODO DE ROCA EN UÑA DE DIQUE LIBERACIÓN PREDIAL LD | 29.5d | 2024-08-26 | 2024-10-01 | 1.07.630 FS+0.5d | 70.55d | 0d | CAPATAZ [30.04 h]; PEON [300.43 h]; Tractor S/Orugas (D6T) - 180 HP [300.43 h]; Excavadora Sobre Oruga 260 HP [300.43 h] |
| 1.03.616 |  | COLOCACION Y ACOMODO DE ROCA EN UÑA DE DIQUE A2-D-01 | 48.5d | 2024-09-13 | 2024-11-11 | 1.07.625 FS+0.5d | 23.05d | 0d | CAPATAZ [2561.2 h]; OPERARIO [2561.2 h]; PEON [2561.2 h]; Excavadora Sobre Oruga 260 HP [3843.89 h] |
|  | 4 | **OBRAS DE ARTE (TOMAS Y RETORNOS)** |  | 2024-08-28 | 2025-02-05 |  |  |  |  |
|  | 1 | **TOMAS O CAPTACIONES** |  | 2024-08-28 | 2025-02-05 |  |  |  |  |
|  | 1 | **OBRAS DE CONCRETO** |  | 2024-10-02 | 2025-02-03 |  |  |  |  |
| 1.04.01 |  | CONCRETO f'c=100 kg/cm2 | 0.53d | 2024-10-02 | 2024-10-02 | 1.08.02 FS+0.5d | 8.81d | 0d | CAPATAZ [6.04 h]; OPERARIO [120.81 h]; PEON [241.56 h]; OFICIAL [60.4 h] |
| 1.04.05 |  | ACERO DE REFUERZO fy=4200 kg/cm2 | 50.65d | 2024-10-03 | 2024-12-03 | 1.04.01 FS+0.53d | 8.81d | 0d | CAPATAZ [161.33 h]; OPERARIO [1613.28 h]; PEON [1613.28 h] |
| 1.04.04 |  | ENCOFRADO Y DESENCOFRADO RECTO | 36.5d | 2024-12-04 | 2025-01-17 | 1.04.05 FS+0.5d | 8.81d | 0d | CAPATAZ [576.93 h]; OPERARIO [1154.04 h]; PEON [1154.04 h] |
| 1.04.02 |  | CONCRETO f'c=280 kg/cm2 | 9.5d | 2025-01-18 | 2025-01-29 | 1.04.04 FS+0.5d | 8.81d | 0d | CAPATAZ [7.92 h]; OPERARIO [158.54 h]; PEON [317.01 h]; OFICIAL [79.27 h] |
| 1.04.03 |  | CONCRETO CICLÓPEO f'c=280 kg/cm2 + 30% P.G. | 3.5d | 2025-01-30 | 2025-02-03 | 1.04.02 FS+0.5d | 10.84d |  | CAPATAZ [6.34 h]; OPERARIO [31.73 h]; PEON [63.44 h]; OFICIAL [48.44 h] |
|  | 3 | **ESTRUCTURAS METÁLICAS** |  | 2025-01-30 | 2025-02-05 |  |  |  |  |
| 1.04.06 |  | COMPUERTA METALICA PLANA DESLIZANTE DE 1.0x1.0 m | 2.5d | 2025-01-30 | 2025-02-01 | 1.04.02 FS+0.5d | 8.81d | 0d | OPERARIO [20 h]; PEON [60 h]; OFICIAL [20 h] |
| 1.04.10 |  | BARANDA DE FIERRO GALVANIZADO 1 1/2" | 0.53d | 2025-01-30 | 2025-01-30 | 1.04.06 SS | 8.81d | 0d | CAPATAZ [0.76 h]; OPERARIO [15.2 h]; PEON [7.6 h]; OFICIAL [15.2 h] |
| 1.04.07 |  | COMPUERTA METALICA PLANA DESLIZANTE DE 1.5x1.0 m | 0.53d | 2025-01-30 | 2025-01-31 | 1.04.06 FS-2d | 12.23d | 0d | OPERARIO [4 h]; PEON [12 h]; OFICIAL [4 h] |
| 1.04.08 |  | REJILLA METÁLICA DE 1.00x1.00m | 0.53d | 2025-01-31 | 2025-02-01 | 1.04.07 FS+0.5d | 12.23d | 0d | OPERARIO [8 h]; PEON [16 h] |
| 1.04.09 |  | REJILLA METÁLICA DE 1.50x1.00m | 0.5d | 2025-01-31 | 2025-02-01 | 1.04.08 FS-0.45d | 12.23d |  | OPERARIO [1.6 h]; PEON [3.2 h] |
| 1.04.11 |  | ESCALERA TIPO GATO | 1.5d | 2025-02-01 | 2025-02-03 | 1.04.10 FS+1.5d | 8.81d | 0d | CAPATAZ [1.2 h]; OPERARIO [12 h]; PEON [24 h] |
| 1.04.12 |  | TAPA DE CONCRETO | 1.5d | 2025-02-04 | 2025-02-05 | 1.04.11 FS+0.5d | 8.81d |  | CAPATAZ [0.96 h]; OPERARIO [9.6 h]; PEON [19.2 h] |

| ID | WBS | Activity | Duration | Start | Finish | Predecessors | Total float | Free float | Resources |
| --- | --- | --- | --- | --- | --- | --- | --- | --- | --- |
|  | 2 | **TUBERÍAS** |  | 2024-08-28 | 2024-11-14 |  |  |  |  |
| 1.04.13 |  | EXCAVACIÓN ESTRUCTURAL PARA OBRAS DE ARTE (buzones) | 1.5d | 2024-08-28 | 2024-08-29 | 1.08.01 SS+0.2d | 77.85d | 0d | CAPATAZ [1.35 h]; CUADRADOR/VIGÍA [13.46 h]; PEON [26.91 h]; Retroexcavador 58 HP [13.46 h] |
| 1.04.14 |  | EXCAVACIÓN DE ZANJA | 15.5d | 2024-08-31 | 2024-09-18 | 1.04.13 FS+0.5d | 77.85d | 0d | CAPATAZ [25.03 h]; CUADRADOR/VIGÍA [250.27 h]; PEON [500.55 h]; Retroexcavador 58 HP [250.27 h] |
| 1.04.16 |  | CAMA DE ARENA | 2.5d | 2024-09-19 | 2024-09-21 | 1.04.14 FS+0.5d | 77.85d | 0d | CAPATAZ [10.71 h]; PEON [85.69 h] |
| 1.04.24 |  | SUMINISTRO E INSTALACIÓN DE TUBERÍA GRP DN600 mm SN2500 | 10.5d | 2024-09-23 | 2024-10-04 | 1.04.16 FS+0.5d | 77.85d | 0d | CAPATAZ [69.33 h]; OPERARIO [302.52 h]; PEON [3465.26 h]; OFICIAL [346.51 h] |
| 1.04.17 |  | RELLENO SELECCIONADO PARA ZANJA con material propio | 7.5d | 2024-10-05 | 2024-10-15 | 1.04.24 FS+0.5d | 77.85d | 0d | CAPATAZ [5.64 h]; CUADRADOR/VIGÍA [56.41 h]; PEON [225.66 h]; Rodillo Vib. Liso Autopropulsado 135 HP 12 TM [56.41 h]; Camión Cisterna 4x2 400 HP Agua (5000 gal) [56.41 h] |
| 1.04.23 |  | ACERO DE REFUERZO fy=4200 kg/cm2 | 3.5d | 2024-10-16 | 2024-10-19 | 1.04.17 FS+0.5d | 77.85d | 0d | CAPATAZ [2.59 h]; OPERARIO [25.94 h]; PEON [25.94 h] |
| 1.04.21 |  | ENCOFRADO Y DESENCOFRADO RECTO | 4.5d | 2024-10-21 | 2024-10-25 | 1.04.23 FS+0.5d | 77.85d | 0d | CAPATAZ [19.41 h]; OPERARIO [38.83 h]; PEON [38.83 h] |
| 1.04.22 |  | ENCOFRADO Y DESENCOFRADO CURVO | 8.5d | 2024-10-26 | 2024-11-06 | 1.04.21 FS+0.5d | 77.85d | 0d | CAPATAZ [34.96 h]; OPERARIO [69.94 h]; PEON [69.94 h] |
| 1.04.20 |  | CONCRETO f'c=280 kg/cm2 (buzones) | 0.5d | 2024-11-07 | 2024-11-07 | 1.04.22 FS+0.5d | 77.85d | 0d | CAPATAZ [0.6 h]; OPERARIO [12.05 h]; PEON [24.1 h]; OFICIAL [6.03 h] |
| 1.04.15 |  | RELLENO ESTRUCTURAL PARA OBRAS DE ARTE, CON MATERIAL PROPIO | 5.5d | 2024-11-08 | 2024-11-14 | 1.04.20 FS+0.5d | 77.85d |  | CAPATAZ [4.49 h]; CUADRADOR/VIGÍA [44.86 h]; PEON [89.7 h]; Rodillo Vib. Liso Autopropulsado 135 HP 12 TM [44.86 h]; Retroexcavador 58 HP [11.22 h] |
|  | 4 | **CANALES** |  | 2024-10-12 | 2024-11-20 |  |  |  |  |
| 1.04.25 |  | CONCRETO f'c=100 kg/cm2 | 0.5d | 2024-10-12 | 2024-10-12 | 1.08.04 FS+0.5d | 72.99d | 0d | CAPATAZ [0.14 h]; OPERARIO [2.72 h]; PEON [5.43 h]; OFICIAL [1.36 h] |
| 1.04.28 |  | ACERO DE REFUERZO fy=4200 kg/cm2 | 16.5d | 2024-10-14 | 2024-11-02 | 1.04.25 FS+0.5d | 72.99d | 0d | CAPATAZ [53.03 h]; OPERARIO [530.28 h]; PEON [530.28 h] |
| 1.04.27 |  | ENCOFRADO Y DESENCOFRADO RECTO | 13.5d | 2024-11-04 | 2024-11-19 | 1.04.28 FS+0.5d | 72.99d | 0d | CAPATAZ [215.75 h]; OPERARIO [431.56 h]; PEON [431.56 h] |
| 1.04.26 |  | CONCRETO f'c=280 kg/cm2 | 0.53d | 2024-11-20 | 2024-11-20 | 1.04.27 FS+0.53d | 72.99d | 0d | CAPATAZ [0.68 h]; OPERARIO [13.71 h]; PEON [27.41 h]; OFICIAL [6.85 h] |
| 1.04.29 |  | JUNTA WATER STOP SIN BULBO 150 mm | 0.53d | 2024-11-20 | 2024-11-20 | 1.04.26 SS | 72.99d |  | OPERARIO [3.94 h] |
|  | 5 | **OBRAS DE DESCARGA** |  | 2024-10-12 | 2024-10-29 |  |  |  |  |
| 1.04.30 |  | CONCRETO f'c=100 kg/cm2 | 0.5d | 2024-10-12 | 2024-10-12 | 1.08.04 FS+0.5d | 90.65d | 0d | CAPATAZ; OPERARIO; PEON; OFICIAL |
| 1.04.33 |  | ACERO DE REFUERZO fy=4200 kg/cm2 | 2.5d | 2024-10-14 | 2024-10-16 | 1.04.30 FS+0.5d | 90.65d | 0d | CAPATAZ [2.18 h]; OPERARIO [21.83 h]; PEON [21.83 h] |
| 1.04.32 |  | ENCOFRADO Y DESENCOFRADO RECTO | 9.5d | 2024-10-17 | 2024-10-28 | 1.04.33 FS+0.5d | 90.65d | 0d | CAPATAZ [39.76 h]; OPERARIO [79.54 h]; PEON [79.54 h] |
| 1.04.31 |  | CONCRETO f'c=280 kg/cm2 | 0.5d | 2024-10-29 | 2024-10-29 | 1.04.32 FS+0.5d | 90.65d | 0d | CAPATAZ [0.14 h]; OPERARIO [2.89 h]; PEON [5.77 h]; OFICIAL [1.44 h] |
| 1.04.34 |  | JUNTA WATER STOP SIN BULBO 150 mm | 0.5d | 2024-10-29 | 2024-10-29 | 1.04.31 FS-0.1d | 90.65d |  | OPERARIO [4.01 h] |
|  | 6 | **RETORNOS** |  | 2024-10-15 | 2024-12-19 |  |  |  |  |
|  | 1 | **RETORNOS TIPO A2-OA-RE-I-11-25** |  | 2024-10-17 | 2024-11-15 |  |  |  |  |
|  | 1 | **OBRAS DE CONCRETO** |  | 2024-10-17 | 2024-11-12 |  |  |  |  |
| 1.04.35 |  | CONCRETO f'c=100 kg/cm2 | 0.5d | 2024-10-17 | 2024-10-17 | 1.08.08 FS+0.5d | 76.78d | 0d | CAPATAZ; OPERARIO; PEON; OFICIAL |
| 1.04.38 |  | ACERO DE REFUERZO fy=4200 kg/cm2 | 9.5d | 2024-10-18 | 2024-10-29 | 1.04.35 FS+0.5d | 76.78d | 0d | CAPATAZ [31.91 h]; OPERARIO [319.06 h]; PEON [319.06 h] |
| 1.04.37 |  | ENCOFRADO Y DESENCOFRADO RECTO | 8.5d | 2024-10-30 | 2024-11-09 | 1.04.38 FS+0.5d | 76.78d | 0d | CAPATAZ [33.04 h]; OPERARIO [66.08 h]; PEON [66.08 h] |
| 1.04.36 |  | CONCRETO f'c=280 kg/cm2 | 0.5d | 2024-11-11 | 2024-11-11 | 1.04.37 FS+0.5d | 76.78d | 0d | CAPATAZ [0.54 h]; OPERARIO [10.83 h]; PEON [21.65 h]; OFICIAL [5.41 h] |
| 1.04.39 |  | JUNTA WATER STOP SIN BULBO 150 mm | 1.59d | 2024-11-11 | 2024-11-12 | 1.04.36 SS | 79.69d |  | OPERARIO [8.02 h] |

| ID | WBS | Activity | Duration | Start | Finish | Predecessors | Total float | Free float | Resources |
| --- | --- | --- | --- | --- | --- | --- | --- | --- | --- |
|  | 2 | **ESTRUCTURAS METALICAS** |  | 2024-11-12 | 2024-11-15 |  |  |  |  |
| 1.04.40 |  | COMPUERTA METALICA PLANA DESLIZANTE DE 1.0x1.0 m | 1.5d | 2024-11-12 | 2024-11-13 | 1.04.36 FS+0.5d | 76.78d | 0d | OPERARIO [12 h]; PEON [36 h]; OFICIAL [12 h] |
| 1.04.41 |  | BARANDA DE FIERRO GALVANIZADO 1 1/2" | 1.5d | 2024-11-14 | 2024-11-15 | 1.04.40 FS+0.5d | 76.78d |  | CAPATAZ [1.22 h]; OPERARIO [24.48 h]; PEON [12.24 h]; OFICIAL [24.48 h] |
|  | 2 | **RETORNOS Q=100 A 1000 l/s** |  | 2024-10-15 | 2024-12-19 |  |  |  |  |
|  | 1 | **OBRAS DE CONCRETO** |  | 2024-10-30 | 2024-11-30 |  |  |  |  |
| 1.04.42 |  | CONCRETO f'c=100 kg/cm2 | 0.53d | 2024-10-30 | 2024-10-30 | 1.08.11 FS+0.47d, 1.04.46 FF-1.5d | 47.83d | 0d | CAPATAZ [0.29 h]; OPERARIO [5.78 h]; PEON [11.56 h]; OFICIAL [2.89 h] |
| 1.04.45 |  | ACERO DE REFUERZO fy=4200 kg/cm2 | 14.76d | 2024-10-31 | 2024-11-18 | 1.04.42 FS+0.42d | 47.83d | 0d | CAPATAZ [45.63 h]; OPERARIO [456.29 h]; PEON [456.29 h] |
| 1.04.44 |  | ENCOFRADO Y DESENCOFRADO RECTO | 9.5d | 2024-11-19 | 2024-11-29 | 1.04.45 FS+0.5d | 47.83d | 0d | CAPATAZ [156.78 h]; OPERARIO [313.62 h]; PEON [313.62 h] |
| 1.04.43 |  | CONCRETO f'c=280 kg/cm2 | 0.5d | 2024-11-30 | 2024-11-30 | 1.04.44 FS+0.5d | 47.83d | 0d | CAPATAZ [0.8 h]; OPERARIO [15.94 h]; PEON [31.87 h]; OFICIAL [7.97 h] |
|  | 2 | **TUBERÍAS** |  | 2024-10-15 | 2024-10-28 |  |  |  |  |
| 1.04.46 |  | SUMINISTRO E INSTALACIÓN DE TUBERÍA HDPE DN600 mm | 11.5d | 2024-10-15 | 2024-10-28 | 1.08.10 FS+0.5d | 51.33d | 3.5d | CAPATAZ [17.9 h]; OPERARIO [178.97 h]; PEON [894.82 h]; OFICIAL [89.48 h] |
|  | 3 | **COMPUERTAS Y VÁLVULAS** |  | 2024-12-02 | 2024-12-19 |  |  |  |  |
| 1.04.47 |  | COMPUERTA TIPO CLAPETA DN600 mm | 15.5d | 2024-12-02 | 2024-12-19 | 1.04.43 FS+0.5d | 47.83d |  | CAPATAZ [12.8 h]; OPERARIO [128 h]; PEON [256 h] |
|  | 5 | **ARQUITECTURA Y PAISAJISMO** |  | 2024-10-23 | 2024-11-05 |  |  |  |  |
|  | 1 | **INTERVENCION PAISAJISMO - CRUCE AVENIDA PERU** |  | 2024-10-23 | 2024-11-05 |  |  |  |  |
|  | 1 | **OBRAS PRELIMINARES** |  | 2024-10-23 | 2024-11-05 |  |  |  |  |
| 1.05.01 |  | MOVILIZACIÓN Y DEMOVILIZACIÓN DE EQUIPOS Y HERRAMIENTAS (ARQUITECTURA Y PAISAJISMO) | 2.5d | 2024-10-23 | 2024-10-25 | 1.05.03 FS-4.5d | 87.94d |  |  |
| 1.05.02 |  | TRAZO Y REPLANTEO PRELIMINAR | 6.5d | 2024-10-28 | 2024-11-05 | 1.05.03 SS-0.1d | 85.97d |  | OPERARIO [2.33 h]; PEON [4.65 h]; TOPOGRAFO [2.33 h] |
|  | 2 | **MOBILIARIOS, BARANDAS Y ESCALERAS** |  | 2024-10-28 | 2024-11-05 |  |  |  |  |
| 1.05.03 |  | ESCALERA DE CONCRETO SOBRE ENROCADO, CIMENTACION Y ANCLAJE | 0.53d | 2024-10-28 | 2024-10-28 | 1.09.22 FS+0.53d | 85.69d | 0d |  |
| 1.05.04 |  | BARANDA DE MADERA EUCALIPTO CON SOGA, INCLUYE CIMENTACIÓN | 0.5d | 2024-10-29 | 2024-10-29 | 1.05.03 FS+0.5d | 85.69d | 0d | CAPATAZ; PEON |
| 1.05.05 |  | TACHOS DE BASURA, INCLUYE CIMENTACIÓN | 0.53d | 2024-10-30 | 2024-10-30 | 1.05.04 FS+0.53d | 85.69d | 0d |  |
| 1.05.06 |  | BANCAS DE CONCRETO, INCLUYE CIMENTACIÓN | 0.53d | 2024-10-31 | 2024-10-31 | 1.05.05 FS+0.53d | 85.69d | 0d |  |
| 1.05.07 |  | POSTES DE ILUMINACIÓN, INCLUYE LUMINARIA Y CIMENTACIÓN | 1.5d | 2024-11-02 | 2024-11-04 | 1.05.06 FS+0.53d | 85.69d | 0d | CAPATAZ [1.6 h]; OPERARIO [1.6 h]; PEON [32 h] |
| 1.05.08 |  | SEÑALETICA INFORMATIVA | 0.5d | 2024-11-05 | 2024-11-05 | 1.05.07 FS+0.5d | 85.69d |  |  |

| ID | WBS | Activity | Duration | Start | Finish | Predecessors | Total float | Free float | Resources |
| --- | --- | --- | --- | --- | --- | --- | --- | --- | --- |
|  | 2 | **SUBPROYECTO A2 TRAMO I (OPCIÓN B)** |  | 2023-11-28 | 2025-02-15 |  |  |  |  |
|  | 1 | **DEFENSAS RIBEREÑAS** |  | 2023-11-28 | 2025-02-15 |  |  |  |  |
|  | 1 | **MEJORAMIENTO DE VÍAS EXISTENTES** |  | 2023-11-28 | 2024-06-04 |  |  |  |  |
| 1.06.01 |  | ROCE Y LIMPIEZA DE MALEZA | 5.5d | 2023-11-28 | 2023-12-04 | A1040 SS-0.4d | 212.67d | 0d | CUADRADOR/VIGÍA [47.41 h]; PEON [189.65 h]; Tractor S/Orugas (D6T) - 180 HP [47.41 h]; CAPATAZ [47.41 h]; Retroexcavador 58 HP [47.41 h]; Camión baranda 3 TON [94.82 h] |
| 1.06.02 |  | REHABILITACIÓN DE VÍAS EXISTENTES | 149.5d | 2023-12-05 | 2024-06-04 | 1.06.01 FS+0.5d | 212.67d |  | CAPATAZ [1194.56 h]; CUADRADOR/VIGÍA [2389.12 h]; PEON [2389.12 h]; Tractor S/Orugas (D6T) - 180 HP [1791.84 h]; OFICIAL [1194.56 h]; Camión Volquete (15 m3) [1194.56 h]; Camión Cisterna 4x2 400 HP Agua (5000 gal) [1194.56 h]; OPERARIO [1194.56 h]; Excavadora Sobre Oruga 260 HP [1194.56 h]; Rodillo Vib. Liso Autopropulsado 135 HP 12 TM [597.28 h] |
| 1.06.03 |  | CONFORMACIÓN DE TERRAPLENES EN CAMINO | 2.53d | 2023-12-05 | 2023-12-07 | 1.06.01 FS+0.5d | 359.64d |  | CAPATAZ [2.7 h]; Excavadora Sobre Oruga 260 HP [2.7 h]; OPERARIO [2.7 h]; PEON [10.79 h]; OFICIAL [2.7 h]; Camión Cisterna 4x2 400 HP Agua (5000 gal) [2.7 h]; Motoniveladora 185 HP [2.7 h]; Rodillo Vib. Liso Autopropulsado 135 HP 12 TM [2.7 h] |
|  | 2 | **DESCOLMATACIÓN DE CAUCE Y OBRAS AUXILIARES** |  | 2023-11-28 | 2024-03-06 |  |  |  |  |
| 1.07.01 |  | DESBROCE Y LIMPIEZA EN ZONA NO BOSCOSA | 16.5d | 2023-11-28 | 2023-12-19 | A1040 SS-0.4d | 351.67d |  | Camión Volquete (15 m3) [254.81 h]; Excavadora Sobre Oruga 260 HP [141.56 h]; OPERARIO [254.81 h]; PEON [1585.48 h]; Tractor S/Orugas (D6T) - 180 HP [254.81 h] |
| 1.07.02 |  | DESCOLMATACIÓN DE DESCOLMATACIÓN DE CAUCE NATURAL DEL RÍO LACRAMARCA | 56.5d | 2023-11-28 | 2024-02-06 | A1040 SS-0.4d | 286.57d | 0d | CUADRADOR/VIGÍA [1814.93 h]; Excavadora Sobre Oruga 260 HP [1814.93 h]; PEON [3629.85 h]; Tractor S/Orugas (D6T) - 180 HP [1814.93 h]; CAPATAZ [172.85 h] |
| 1.07.03 |  | CONFORMACIÓN DE DESVIO EN CAUCE DE RÍO | 34.5d | 2023-12-05 | 2024-01-18 | 1.07.02 SS+6d | 286.57d | 0d | CAPATAZ [1109.52 h]; CUADRADOR/VIGÍA [1109.52 h]; Excavadora Sobre Oruga 260 HP [1109.52 h]; OPERARIO [1109.52 h]; Tractor S/Orugas (D6T) - 180 HP [546.48 h] |
| 1.07.04 |  | RELLENO NO ESTRUCTURAL CON MATERIAL PROPIO (canal) | 46.5d | 2024-01-12 | 2024-03-06 | 1.07.03 FS-5.4d | 286.57d |  | CAPATAZ [364.55 h]; PEON [1474.77 h]; Rodillo Vib. Liso Autopropulsado 135 HP 12 TM [729.1 h]; OPERARIO [729.1 h]; Camión Cisterna 4x2 400 HP Agua (5000 gal) [729.1 h]; Tractor S/Orugas (D6T) - 180 HP [729.1 h] |
|  | 3 | **DIQUES DE TIERRA COMPACTADA CON ENROCADO** |  | 2023-11-28 | 2025-01-21 |  |  |  |  |
|  | 1 | **EXCAVACIÓN EN TERRENO NATURAL CON EQUIPO** |  | 2023-11-28 | 2024-05-07 |  |  |  |  |
| 1.07.100 |  | EXCAVACIÓN EN TERRENO NATURAL CON EQUIPO (A2-I-01) | 8.5d | 2023-11-28 | 2023-12-07 | 01.02.01 SS+3d | 8.81d | 0d | CAPATAZ [26.04 h]; PEON [260.4 h]; Tractor S/Orugas (D6T) - 180 HP [260.4 h]; Excavadora Sobre Oruga 260 HP [260.4 h] |
| 1.07.200 |  | EXCAVACIÓN EN TERRENO NATURAL CON EQUIPO (A2-I-01-B) | 1.5d | 2023-11-28 | 2023-11-29 | 01.02.01 SS+3d | 0d |  | CAPATAZ [2.41 h]; PEON [24.06 h]; Tractor S/Orugas (D6T) - 180 HP [24.06 h]; Excavadora Sobre Oruga 260 HP [24.06 h] |
| 1.07.400 |  | EXCAVACIÓN EN TERRENO NATURAL CON EQUIPO (A2-I-02) | 51.5d | 2023-12-02 | 2024-02-05 | 1.07.172 FS+0.5d | 0d |  | CAPATAZ [138.03 h]; PEON [1380.31 h]; Tractor S/Orugas (D6T) - 180 HP [1380.31 h]; Excavadora Sobre Oruga 260 HP [1380.31 h] |
| 1.07.300 |  | EXCAVACIÓN EN TERRENO NATURAL CON EQUIPO (A2-I-03) | 8.5d | 2023-12-13 | 2023-12-22 | 1.07.171 FS+0.5d | 8.81d | 0d | CAPATAZ [51.35 h]; PEON [513.48 h]; Tractor S/Orugas (D6T) - 180 HP [513.48 h]; Excavadora Sobre Oruga 260 HP [513.48 h] |
| 1.07.500 |  | EXCAVACIÓN EN TERRENO NATURAL CON EQUIPO (A2-D-01) | 55.5d | 2023-12-27 | 2024-03-01 | 1.07.173 FS+0.5d | 8.81d | 0d | CAPATAZ [223.6 h]; PEON [2235.97 h]; Tractor S/Orugas (D6T) - 180 HP [2235.97 h]; Excavadora Sobre Oruga 260 HP [2235.97 h] |
| 1.07.600 |  | EXCAVACIÓN EN TERRENO NATURAL CON EQUIPO (A2-D-02) | 4.5d | 2024-03-04 | 2024-03-08 | 1.07.174 FS+0.5d | 206.05d | 0d | CAPATAZ [30.04 h]; PEON [300.43 h]; Tractor S/Orugas (D6T) - 180 HP [300.43 h]; Excavadora Sobre Oruga 260 HP [300.43 h] |
| 1.07.710 |  | EXCAVACIÓN INTERFERENCIA SEDACHIMBOTE | 10.5d | 2024-03-11 | 2024-03-22 | 1.07.176 FS+0.5d | 206.05d | 0d | CAPATAZ [24.98 h]; PEON [249.8 h]; Tractor S/Orugas (D6T) - 180 HP [250 h]; Excavadora Sobre Oruga 260 HP [249.8 h] |
| 1.07.750 |  | EXCAVACIÓN LIBERACIÓN PREDIAL LD | 36.5d | 2024-03-22 | 2024-05-07 | 1.07.175 FS+0.5d | 8.81d | 0d | CAPATAZ [86 h]; PEON [866 h]; Tractor S/Orugas (D6T) - 180 HP [866 h]; Excavadora Sobre Oruga 260 HP [866 h] |
| 1.07.720 |  | EXCAVACIÓN INTERFERENCIA QUAVI | 7.5d | 2024-03-30 | 2024-04-08 | 1.07.177 FS+0.5d | 206.05d | 0d | CAPATAZ [17.69 h]; PEON [176.9 h]; Tractor S/Orugas (D6T) - 180 HP [176.9 h]; Excavadora Sobre Oruga 260 HP [176.9 h] |
| 1.07.730 |  | EXCAVACIÓN LIBERACIÓN PREDIAL LI | 13.5d | 2024-04-11 | 2024-04-26 | 1.07.178 FS+0.5d | 206.05d | 0d | CAPATAZ [32.19 h]; PEON [321 h]; Tractor S/Orugas (D6T) - 180 HP [321 h]; Excavadora Sobre Oruga 260 HP [321 h] |
| 1.07.800 |  | EXCAVACIÓN EN TERRENO NATURAL CON EQUIPO (RAMPAS) | 0.5d | 2024-04-30 | 2024-04-30 | 1.07.179 FS+0.5d | 236.05d | 0d | CAPATAZ; PEON; Tractor S/Orugas (D6T) - 180 HP; Excavadora Sobre Oruga 260 HP |

| ID | WBS | Activity | Duration | Start | Finish | Predecessors | Total float | Free float | Resources |
| --- | --- | --- | --- | --- | --- | --- | --- | --- | --- |
|  | 2 | **EXCAVACIÓN DE UÑA CON EQUIPO** |  | 2023-11-30 | 2024-05-20 |  |  |  |  |
| 1.07.172 |  | EXCAVACIÓN DE UÑA CON EQUIPO (A2-I-01-B) | 1.5d | 2023-11-30 | 2023-12-01 | 1.07.200 FS+0.5d | 0d |  | CAPATAZ [59.37 h]; Excavadora Sobre Oruga 260 HP [593.67 h]; PEON [593.67 h] |
| 1.07.171 |  | EXCAVACIÓN DE UÑA CON EQUIPO (A2-I-01) | 1.5d | 2023-12-11 | 2023-12-12 | 1.07.100 FS+0.5d | 8.81d | 0d | CAPATAZ [4.59 h]; Excavadora Sobre Oruga 260 HP [45.95 h]; PEON [45.95 h] |
| 1.07.173 |  | EXCAVACIÓN DE UÑA CON EQUIPO (A2-I-03) | 1.5d | 2023-12-23 | 2023-12-26 | 1.07.300 FS+0.5d | 8.81d | 0d | CAPATAZ [6.64 h]; Excavadora Sobre Oruga 260 HP [66.37 h]; PEON [66.37 h] |
| 1.07.174 |  | EXCAVACIÓN DE UÑA CON EQUIPO (A2-I-02) | 22.5d | 2024-02-06 | 2024-03-02 | 1.07.400 FS+0.5d | 0d |  | CAPATAZ [59.37 h]; Excavadora Sobre Oruga 260 HP [593.67 h]; PEON [593.67 h] |
| 1.07.175 |  | EXCAVACIÓN DE UÑA CON EQUIPO (A2-D-01) | 16.5d | 2024-03-02 | 2024-03-21 | 1.07.500 FS+0.5d | 8.81d | 0d | CAPATAZ [66.63 h]; Excavadora Sobre Oruga 260 HP [666.33 h]; PEON [666.33 h] |
| 1.07.176 |  | EXCAVACIÓN DE UÑA CON EQUIPO (A2-D-02) | 0.5d | 2024-03-09 | 2024-03-09 | 1.07.600 FS+0.5d | 206.05d | 0d | CAPATAZ [6.75 h]; Excavadora Sobre Oruga 260 HP [67.5 h]; PEON [67.5 h] |
| 1.07.177 |  | EXCAVACIÓN DE UÑA CON EQUIPO INTERFERENCIA SEDACHIMBOTE | 3.5d | 2024-03-23 | 2024-03-27 | 1.07.710 FS+0.5d | 206.05d | 0d | CAPATAZ [9.27 h]; PEON [92.68 h]; Tractor S/Orugas (D6T) - 180 HP [92.68 h]; Excavadora Sobre Oruga 260 HP [92.68 h] |
| 1.07.178 |  | EXCAVACIÓN DE UÑA CON EQUIPO INTERFERENCIA QUAVI | 1.5d | 2024-04-09 | 2024-04-10 | 1.07.720 FS+0.5d | 206.05d | 0d | CAPATAZ [448 h]; PEON [4480 h]; Tractor S/Orugas (D6T) - 180 HP [4480 h]; Excavadora Sobre Oruga 260 HP [4480 h] |
| 1.07.179 |  | EXCAVACIÓN DE UÑA CON EQUIPO LIBERACIÓN PREDIAL LI | 1.5d | 2024-04-27 | 2024-04-29 | 1.07.730 FS+0.5d | 206.05d | 0d | CAPATAZ [458 h]; PEON [4576 h]; Tractor S/Orugas (D6T) - 180 HP [4576 h]; Excavadora Sobre Oruga 260 HP [4576 h] |
| 1.07.180 |  | EXCAVACIÓN DE UÑA CON EQUIPO LIBERACIÓN PREDIAL LD | 10.5d | 2024-05-08 | 2024-05-20 | 1.07.750 FS+0.5d | 8.81d | 0d | CAPATAZ [24.38 h]; PEON [243 h]; Tractor S/Orugas (D6T) - 180 HP [243 h]; Excavadora Sobre Oruga 260 HP [243 h] |
|  | 3 | **PERFILADO Y COMPACTACIÓN EN ZONA DE CORTE EN CORONA** |  | 2023-12-21 | 2025-01-21 |  |  |  |  |
| 1.07.232 |  | PERFILADO Y COMPACTACIÓN EN ZONA DE CORTE EN CORONA (A2-I-01-B) | 0.53d | 2023-12-21 | 2023-12-21 | 1.07.552 FS+0.5d | 350.02d |  | CAPATAZ; Excavadora Sobre Oruga 260 HP; PEON; Rodillo Vib. Liso Autopropulsado 135 HP 12 TM; Motoniveladora 185 HP; Camión Cisterna 4x2 400 HP Agua (5000 gal) |
| 1.07.233 |  | PERFILADO Y COMPACTACIÓN EN ZONA DE CORTE EN CORONA (A2-I-03) | 0.5d | 2024-01-23 | 2024-01-23 | 1.07.553 FS+0.5d | 324.05d |  | CAPATAZ [1.56 h]; Excavadora Sobre Oruga 260 HP [4.15 h]; PEON [16.59 h]; Rodillo Vib. Liso Autopropulsado 135 HP 12 TM [16.59 h]; Motoniveladora 185 HP [8.3 h]; Camión Cisterna 4x2 400 HP Agua (5000 gal) [4.15 h] |
| 1.07.236 |  | PERFILADO Y COMPACTACIÓN EN ZONA DE CORTE EN CORONA (A2-D-02) | 0.5d | 2024-04-04 | 2024-04-04 | 1.07.556 FS+0.5d | 264.05d |  | CAPATAZ [1.64 h]; Excavadora Sobre Oruga 260 HP [4.38 h]; PEON [17.53 h]; Rodillo Vib. Liso Autopropulsado 135 HP 12 TM [17.53 h]; Motoniveladora 185 HP [8.77 h]; Camión Cisterna 4x2 400 HP Agua (5000 gal) [4.38 h] |
| 1.07.820 |  | PERFILADO Y COMPACTACIÓN EN ZONA DE CORTE EN CORONA INTERFERENCIA QUAVI | 0.5d | 2024-05-27 | 2024-05-27 | 1.07.558 FS+0.5d | 220.05d |  | CAPATAZ [0.21 h]; PEON [2.21 h]; Excavadora Sobre Oruga 260 HP [0.55 h]; Motoniveladora 185 HP [2.21 h]; Camión Cisterna 4x2 400 HP Agua (5000 gal) [0.55 h] |
| 1.07.810 |  | PERFILADO Y COMPACTACIÓN EN ZONA DE CORTE EN CORONA INTERFERENCIA SEDACHIMBOTE | 0.5d | 2024-06-06 | 2024-06-06 | 1.07.557 FS+0.5d | 211.05d | 0d | CAPATAZ [0.5 h]; PEON [5.28 h]; Excavadora Sobre Oruga 260 HP [1.32 h]; Motoniveladora 185 HP [2.64 h]; Camión Cisterna 4x2 400 HP Agua (5000 gal) [1.31 h] |
| 1.07.830 |  | PERFILADO Y COMPACTACIÓN EN ZONA DE CORTE EN CORONA LIBERACIÓN PREDIAL LI | 1.5d | 2024-06-11 | 2024-06-12 | 1.07.559 FS+0.5d | 206.05d |  | CAPATAZ [0.96 h]; PEON [10.26 h]; Excavadora Sobre Oruga 260 HP [2.57 h]; Motoniveladora 185 HP [5.13 h]; Camión Cisterna 4x2 400 HP Agua (5000 gal) [2.57 h] |
| 1.07.840 |  | PERFILADO Y COMPACTACIÓN EN ZONA DE CORTE EN CORONA LIBERACIÓN PREDIAL LD | 3.5d | 2024-11-19 | 2024-11-23 | 1.07.560 FS+0.5d | 70.55d | 0d | CAPATAZ [2.31 h]; PEON [24 h]; Excavadora Sobre Oruga 260 HP [6.16 h]; Motoniveladora 185 HP [12.33 h]; Camión Cisterna 4x2 400 HP Agua (5000 gal) [6.16 h] |
| 1.07.235 |  | PERFILADO Y COMPACTACIÓN EN ZONA DE CORTE EN CORONA (A2-D-01) | 3.5d | 2025-01-16 | 2025-01-20 | 1.07.555 FS+0.5d | 23.05d | 0d | CAPATAZ [4.14 h]; Excavadora Sobre Oruga 260 HP [11.05 h]; PEON [44.19 h]; Rodillo Vib. Liso Autopropulsado 135 HP 12 TM [44.19 h]; Motoniveladora 185 HP [22.09 h]; Camión Cisterna 4x2 400 HP Agua (5000 gal) [11.05 h] |
| 1.07.234 |  | PERFILADO Y COMPACTACIÓN EN ZONA DE CORTE EN CORONA (A2-I-02) | 3.5d | 2025-01-17 | 2025-01-21 | 1.07.554 FS+0.5d | 0d |  | CAPATAZ [2.88 h]; Excavadora Sobre Oruga 260 HP [7.68 h]; PEON [30.74 h]; Rodillo Vib. Liso Autopropulsado 135 HP 12 TM [30.74 h]; Motoniveladora 185 HP [15.37 h]; Camión Cisterna 4x2 400 HP Agua (5000 gal) [7.68 h] |
|  | 10 | **PERFILADO EN ZONA DE CORTE EN TALUD DE DIQUE** |  | 2023-12-05 | 2024-08-26 |  |  |  |  |
| 1.07.292 |  | PERFILADO EN ZONA DE CORTE TALUD DE DIQUE (A2-I-01-B) | 1.5d | 2023-12-05 | 2023-12-06 | 1.07.452 FS+0.5d | 45.55d | 0d | CAPATAZ [1.52 h]; Excavadora Sobre Oruga 260 HP [3.43 h]; PEON [13.7 h]; Rodillo Vib. Liso Autopropulsado 135 HP 12 TM [13.7 h]; Motoniveladora 185 HP [6.85 h]; Camión Cisterna 4x2 400 HP Agua (5000 gal) [6.85 h] |
| 1.07.293 |  | PERFILADO EN ZONA DE CORTE TALUD DE DIQUE (A2-I-03) | 3.5d | 2023-12-30 | 2024-01-04 | 1.07.453 FS+0.5d | 324.05d | 0d | CAPATAZ [6.94 h]; Excavadora Sobre Oruga 260 HP [15.61 h]; PEON [62.44 h]; Rodillo Vib. Liso Autopropulsado 135 HP 12 TM [62.44 h]; Motoniveladora 185 HP [31.22 h]; Camión Cisterna 4x2 400 HP Agua (5000 gal) [31.22 h] |
| 1.07.291 |  | PERFILADO EN ZONA DE CORTE DE TALUD DE DIQUE (A2-I-01) | 2.5d | 2024-01-17 | 2024-01-19 | 1.07.491 FS+0.5d | 314.05d | 0d | CAPATAZ [2.44 h]; Excavadora Sobre Oruga 260 HP [5.5 h]; PEON [22 h]; Rodillo Vib. Liso Autopropulsado 135 HP 12 TM [22 h]; Motoniveladora 185 HP [11 h]; Camión Cisterna 4x2 400 HP Agua (5000 gal) [11 h] |
| 1.07.296 |  | PERFILADO EN ZONA DE CORTE DE TALUD DE DIQUE (A2-D-02) | 3.5d | 2024-03-13 | 2024-03-16 | 1.07.456 FS+0.5d | 264.05d | 0d | CAPATAZ [7.74 h]; Excavadora Sobre Oruga 260 HP [17.42 h]; PEON [69.68 h]; Rodillo Vib. Liso Autopropulsado 135 HP 12 TM [69.68 h]; Motoniveladora 185 HP [34.84 h]; Camión Cisterna 4x2 400 HP Agua (5000 gal) [34.84 h] |
| 1.07.850 |  | PERFILADO EN ZONA DE CORTE DE TALUD DE DIQUE INTERFERENCIA SEDACHIMBOTE | 5.5d | 2024-04-24 | 2024-04-30 | 1.07.494 FS+0.5d | 211.05d | 0d | CAPATAZ [4.4 h]; PEON [39.6 h]; Excavadora Sobre Oruga 260 HP [9.9 h]; Camión Cisterna 4x2 400 HP Agua (5000 gal) [19.8 h]; Rodillo Vib. Liso Autopropulsado 135 HP 12 TM [39.6 h]; Motoniveladora 185 HP [19.8 h] |
| 1.07.860 |  | PERFILADO EN ZONA DE CORTE DE TALUD DE DIQUE QUAVI | 2.5d | 2024-05-06 | 2024-05-08 | 1.07.495 FS+0.5d | 220.05d | 0d | CAPATAZ [223.6 h]; PEON [2235.97 h]; Excavadora Sobre Oruga 260 HP [2235.97 h]; Camión Cisterna 4x2 400 HP Agua (5000 gal) [21.25 h]; Motoniveladora 185 HP [21.25 h] |
| 1.07.870 |  | PERFILADO EN ZONA DE CORTE DE TALUD DE DIQUE LIBERACIÓN PREDIAL LI | 5.5d | 2024-05-09 | 2024-05-15 | 1.07.496 FS+0.5d | 206.05d | 0d | CAPATAZ [4.44 h]; PEON [39.92 h]; Excavadora Sobre Oruga 260 HP [9.98 h]; Camión Cisterna 4x2 400 HP Agua (5000 gal) [19.66 h]; Rodillo Vib. Liso Autopropulsado 135 HP 12 TM [39.92 h]; Motoniveladora 185 HP [19.96 h] |
| 1.07.294 |  | PERFILADO EN ZONA DE CORTE TALUD DE DIQUE (A2-I-02) | 13.5d | 2024-06-17 | 2024-07-03 | 1.07.492 FS+0.5d | 0d |  | CAPATAZ [27.31 h]; Excavadora Sobre Oruga 260 HP [61.45 h]; PEON [245.8 h]; Rodillo Vib. Liso Autopropulsado 135 HP 12 TM [245.8 h]; Motoniveladora 185 HP [122.9 h]; Camión Cisterna 4x2 400 HP Agua (5000 gal) [122.9 h] |
| 1.07.880 |  | PERFILADO EN ZONA DE CORTE DE TALUD DE DIQUE LIBERACIÓN PREDIAL LD | 8.5d | 2024-08-03 | 2024-08-14 | 1.07.497 FS+0.5d | 70.55d | 0d | CAPATAZ [15 h]; PEON [135 h]; Excavadora Sobre Oruga 260 HP [33 h]; Camión Cisterna 4x2 400 HP Agua (5000 gal) [67 h]; Rodillo Vib. Liso Autopropulsado 135 HP 12 TM [135 h]; Motoniveladora 185 HP [67 h] |
| 1.07.295 |  | PERFILADO EN ZONA DE CORTE EN TALUD DE DIQUE (A2-D-01) | 11.5d | 2024-08-13 | 2024-08-26 | 1.07.493 FS+0.5d | 23.05d | 0d | CAPATAZ [33.38 h]; Excavadora Sobre Oruga 260 HP [75.11 h]; PEON [300.44 h]; Rodillo Vib. Liso Autopropulsado 135 HP 12 TM [300.44 h]; Motoniveladora 185 HP [150.22 h]; Camión Cisterna 4x2 400 HP Agua (5000 gal) [150.22 h] |

| ID | WBS | Activity | Duration | Start | Finish | Predecessors | Total float | Free float | Resources |
| --- | --- | --- | --- | --- | --- | --- | --- | --- | --- |
|  | 11 | **PREPARACIÓN DE FUNDACIÓN DE CUERPO DE DIQUE** |  | 2023-12-02 | 2024-05-21 |  |  |  |  |
| 1.07.331 |  | PREPARACIÓN DE FUNDACIÓN DE CUERPO DE DIQUE (A2-I-01-B) | 0.5d | 2023-12-02 | 2023-12-02 | 1.07.172 FS+0.5d | 45.55d | 0d | Camión Cisterna 4x2 400 HP Agua (5000 gal) [0.29 h]; CAPATAZ [0.11 h]; Motoniveladora 185 HP [0.59 h]; PEON [1.17 h]; Rodillo Vib. Liso Autopropulsado 135 HP 12 TM [1.17 h]; Excavadora Sobre Oruga 260 HP [0.29 h] |
| 1.07.332 |  | PREPARACIÓN DE FUNDACIÓN DE CUERPO DE DIQUE (A2-I-03) | 0.5d | 2023-12-27 | 2023-12-27 | 1.07.173 FS+0.5d | 324.05d | 0d | Camión Cisterna 4x2 400 HP Agua (5000 gal) [1.57 h]; CAPATAZ [0.59 h]; Motoniveladora 185 HP [3.14 h]; PEON [6.29 h]; Rodillo Vib. Liso Autopropulsado 135 HP 12 TM [6.29 h]; Excavadora Sobre Oruga 260 HP [1.57 h] |
| 1.07.333 |  | PREPARACIÓN DE FUNDACIÓN DE CUERPO DE DIQUE (A2-I-02) | 4.24d | 2024-03-04 | 2024-03-08 | 1.07.174 FS+0.5d | 0d |  | Camión Cisterna 4x2 400 HP Agua (5000 gal) [23.92 h]; CAPATAZ [5.31 h]; Motoniveladora 185 HP [23.92 h]; PEON [47.83 h]; Rodillo Vib. Liso Autopropulsado 135 HP 12 TM [47.83 h]; Excavadora Sobre Oruga 260 HP [11.96 h] |
| 1.07.334 |  | PREPARACIÓN DE FUNDACIÓN DE CUERPO DE DIQUE (A2-D-02) | 0.5d | 2024-03-11 | 2024-03-11 | 1.07.176 FS+0.5d | 264.05d | 0d | Camión Cisterna 4x2 400 HP Agua (5000 gal) [1.51 h]; CAPATAZ [0.57 h]; Motoniveladora 185 HP [3.02 h]; PEON [6.04 h]; Rodillo Vib. Liso Autopropulsado 135 HP 12 TM [6.04 h]; Excavadora Sobre Oruga 260 HP [1.51 h] |
| 1.07.890 |  | PREPARACIÓN DE FUNDACIÓN DE CUERPO DE DIQUE INTERFERENCIA SEDACHIMBOTE | 0.5d | 2024-03-30 | 2024-03-30 | 1.07.177 FS+0.5d | 211.05d | 0d | CAPATAZ [30.04 h]; PEON [300.43 h]; Excavadora Sobre Oruga 260 HP [300.43 h]; Motoniveladora 185 HP [4.25 h]; Rodillo Vib. Liso Autopropulsado 135 HP 12 TM [4.25 h]; Camión Cisterna 4x2 400 HP Agua (5000 gal) [4.25 h] |
| 1.07.910 |  | PREPARACIÓN DE FUNDACIÓN DE CUERPO DE DIQUE LIBERACIÓN PREDIAL LI | 0.5d | 2024-04-30 | 2024-04-30 | 1.07.179 FS+0.5d | 206.05d | 0d | CAPATAZ [30.04 h]; PEON [300.43 h]; Excavadora Sobre Oruga 260 HP [300.43 h]; Motoniveladora 185 HP [4.25 h]; Rodillo Vib. Liso Autopropulsado 135 HP 12 TM [4.25 h]; Camión Cisterna 4x2 400 HP Agua (5000 gal) [4.25 h] |
| 1.07.911 |  | PREPARACIÓN DE FUNDACIÓN DE CUERPO DE DIQUE LIBERACIÓN PREDIAL LD | 0.5d | 2024-05-21 | 2024-05-21 | 1.07.180 FS+0.5d | 70.55d | 0d | CAPATAZ [30.04 h]; PEON [300.43 h]; Excavadora Sobre Oruga 260 HP [300.43 h]; Motoniveladora 185 HP [4.25 h]; Rodillo Vib. Liso Autopropulsado 135 HP 12 TM [4.25 h]; Camión Cisterna 4x2 400 HP Agua (5000 gal) [4.25 h] |
|  | 4 | **PEDRAPLÉN e=60 cm** |  | 2023-12-13 | 2024-06-27 |  |  |  |  |
| 1.07.361 |  | PEDRAPLEN e=60 cm (A2-I-01) | 13.5d | 2023-12-13 | 2023-12-29 | 1.07.171 FS+0.5d | 25.85d | 0d | CAPATAZ [29.02 h]; OPERARIO [287.02 h]; PEON [2866.99 h]; OFICIAL [287.02 h]; CARGADOR SOBRE LLANTAS DE 200-250 HP [287.02 h]; Excavadora Sobre Oruga 320 [287 h] |
| 1.07.362 |  | PEDRAPLÉN e=60 cm (A2-I-02) | 15.5d | 2024-03-09 | 2024-03-27 | 1.07.333 FS+1d | 0d |  | CAPATAZ [27.79 h]; OPERARIO [274.85 h]; PEON [2745.41 h]; OFICIAL [274.85 h]; CARGADOR SOBRE LLANTAS DE 200-250 HP [274.85 h]; Excavadora Sobre Oruga 320 [275 h] |
| 1.07.363 |  | PEDRAPLEN e=60 cm (A2-D-01) | 62.5d | 2024-03-22 | 2024-06-06 | 1.07.175 FS+0.5d | 23.05d | 0d | CAPATAZ [168.13 h]; OPERARIO [1662.58 h]; PEON [16607.1 h]; OFICIAL [1662.58 h]; CARGADOR SOBRE LLANTAS DE 200-250 HP [1662.58 h]; Excavadora Sobre Oruga 320 [1663 h] |
| 1.07.930 |  | PEDRAPLEN e=60 cm INTERFERENCIA SEDACHIMBOTE | 6.5d | 2024-04-01 | 2024-04-08 | 1.07.890 FS+0.5d | 211.05d | 0d | CAPATAZ [30.04 h]; PEON [300.43 h]; Tractor S/Orugas (D6T) - 180 HP [300.43 h]; Excavadora Sobre Oruga 260 HP [300.43 h] |
| 1.07.940 |  | PEDRAPLEN e=60 cm INTERFERENCIA QUAVI | 9.5d | 2024-04-11 | 2024-04-22 | 1.07.178 FS+0.5d | 220.05d | 0d | CAPATAZ [223.6 h]; PEON [2235.97 h]; Tractor S/Orugas (D6T) - 180 HP [2235.97 h]; Excavadora Sobre Oruga 260 HP [2235.97 h] |
| 1.07.950 |  | PEDRAPLEN e=60 cm LIBERACIÓN PREDIAL LI | 0.5d | 2024-05-02 | 2024-05-02 | 1.07.910 FS+0.5d | 206.05d | 0d | CAPATAZ [30.04 h]; PEON [300.43 h]; Tractor S/Orugas (D6T) - 180 HP [300.43 h]; Excavadora Sobre Oruga 260 HP [300.43 h] |
| 1.07.960 |  | PEDRAPLEN e=60 cm LIBERACIÓN PREDIAL LD | 31.5d | 2024-05-21 | 2024-06-27 | 1.07.911 | 70.55d | 0d | CAPATAZ [30.04 h]; PEON [300.43 h]; Tractor S/Orugas (D6T) - 180 HP [300.43 h]; Excavadora Sobre Oruga 260 HP [300.43 h] |
|  | 5 | **PEDRAPLÉN e=30 cm** |  | 2023-12-30 | 2024-07-04 |  |  |  |  |
| 1.07.391 |  | PEDRAPLEN e=30 cm (A2-I-01) | 1.5d | 2023-12-30 | 2024-01-02 | 1.07.361 FS+0.5d | 314.05d | 0d | CAPATAZ [4.05 h]; OPERARIO [40.05 h]; PEON [400.02 h]; OFICIAL [40.05 h]; CARGADOR SOBRE LLANTAS DE 200-250 HP [40.05 h]; Excavadora Sobre Oruga 320 [40 h] |
| 1.07.392 |  | PEDRAPLEN e=30 cm (A2-I-02) | 7.5d | 2024-03-30 | 2024-04-08 | 1.07.362 FS+0.5d | 0d |  | OPERARIO [140.97 h]; PEON [1408.1 h]; OFICIAL [140.97 h]; CARGADOR SOBRE LLANTAS DE 200-250 HP [140.97 h]; CAPATAZ [14.26 h]; Excavadora Sobre Oruga 320 [141 h] |
| 1.07.970 |  | PEDRAPLEN e=30 cm INTERFERENCIA SEDACHIMBOTE | 1.5d | 2024-04-09 | 2024-04-10 | 1.07.930 FS+0.5d | 211.05d | 0d | CAPATAZ [30.04 h]; PEON [300.43 h]; Tractor S/Orugas (D6T) - 180 HP [300.43 h]; Excavadora Sobre Oruga 260 HP [300.43 h] |
| 1.07.980 |  | PEDRAPLEN e=30 cm INTERFERENCIA QUAVI | 1.5d | 2024-04-23 | 2024-04-24 | 1.07.940 FS+0.5d | 220.05d | 0d | CAPATAZ [223.6 h]; PEON [2235.97 h]; Tractor S/Orugas (D6T) - 180 HP [2235.97 h]; Excavadora Sobre Oruga 260 HP [2235.97 h] |
| 1.07.990 |  | PEDRAPLEN e=30 cm LIBERACIÓN PREDIAL LI | 0.5d | 2024-05-03 | 2024-05-03 | 1.07.950 FS+0.5d | 206.05d | 0d | CAPATAZ [30.04 h]; PEON [300.43 h]; Tractor S/Orugas (D6T) - 180 HP [300.43 h]; Excavadora Sobre Oruga 260 HP [300.43 h] |
| 1.07.393 |  | PEDRAPLEN e=30 cm (A2-D-01) | 8.5d | 2024-06-07 | 2024-06-17 | 1.07.363 FS+0.5d | 23.05d | 0d | CAPATAZ [22.43 h]; OPERARIO [221.82 h]; PEON [2215.74 h]; OFICIAL [221.82 h]; CARGADOR SOBRE LLANTAS DE 200-250 HP [221.82 h]; Excavadora Sobre Oruga 320 [222 h] |
| 1.07.991 |  | PEDRAPLEN e=30 cm LIBERACIÓN PREDIAL LD | 4.5d | 2024-06-27 | 2024-07-04 | 1.07.960 FS+0.5d | 70.55d | 0d | CAPATAZ [30.04 h]; PEON [300.43 h]; Tractor S/Orugas (D6T) - 180 HP [300.43 h]; Excavadora Sobre Oruga 260 HP [300.43 h] |

| ID | WBS | Activity | Duration | Start | Finish | Predecessors | Total float | Free float | Resources |
| --- | --- | --- | --- | --- | --- | --- | --- | --- | --- |
|  | 6 | **CONFORMACIÓN DE CUERPO DE DIQUE CON MATERIAL PROPIO** |  | 2023-12-04 | 2024-08-07 |  |  |  |  |
| 1.07.452 |  | CONFORMACIÓN DE CUERPO DE DIQUE CON MATERIAL PROPIO (A2-I-01-B) | 0.5d | 2023-12-04 | 2023-12-04 | 1.07.331 FS+0.5d, A1050 SF | 45.55d | 0d | Camión Cisterna 4x2 400 HP Agua (5000 gal) [1.22 h]; CAPATAZ [2.45 h]; Motoniveladora 185 HP [2.45 h]; OPERARIO [2.45 h]; PEON [9.79 h]; Rodillo Vib. Liso Autopropulsado 135 HP 12 TM [2.45 h]; OFICIAL [2.45 h]; Excavadora Sobre Oruga 260 HP [2.45 h]; CARGADOR SOBRE LLANTAS DE 200-250 HP [1.22 h] |
| 1.07.453 |  | CONFORMACIÓN DE CUERPO DE DIQUE CON MATERIAL PROPIO (A2-I-03) | 1.5d | 2023-12-28 | 2023-12-29 | 1.07.332 FS+0.5d | 324.05d | 0d | Camión Cisterna 4x2 400 HP Agua (5000 gal) [21.23 h]; CAPATAZ [42.63 h]; Motoniveladora 185 HP [42.63 h]; OPERARIO [42.63 h]; PEON [170.35 h]; Rodillo Vib. Liso Autopropulsado 135 HP 12 TM [42.63 h]; OFICIAL [42.63 h]; Excavadora Sobre Oruga 260 HP [42.63 h]; CARGADOR SOBRE LLANTAS DE 200-250 HP [21.23 h] |
| 1.07.451 |  | CONFORMACIÓN DE CUERPO DE DIQUE CON MATERIAL PROPIO (A2-I-01) | 9.5d | 2024-01-03 | 2024-01-13 | 1.07.391 FS+0.5d | 314.05d | 0d | Camión Cisterna 4x2 400 HP Agua (5000 gal) [96.91 h]; CAPATAZ [194.55 h]; Motoniveladora 185 HP [194.55 h]; OPERARIO [194.55 h]; PEON [777.47 h]; Rodillo Vib. Liso Autopropulsado 135 HP 12 TM [194.55 h]; OFICIAL [194.55 h]; Excavadora Sobre Oruga 260 HP [194.55 h]; CARGADOR SOBRE LLANTAS DE 200-250 HP [96.91 h] |
| 1.07.456 |  | CONFORMACIÓN DE CUERPO DE DIQUE CON MATERIAL PROPIO (A2-D-02) | 0.5d | 2024-03-12 | 2024-03-12 | 1.07.334 FS+0.5d | 264.05d | 0d | Camión Cisterna 4x2 400 HP Agua (5000 gal) [19.53 h]; CAPATAZ [39.21 h]; Motoniveladora 185 HP [39.21 h]; OPERARIO [39.21 h]; PEON [156.68 h]; Rodillo Vib. Liso Autopropulsado 135 HP 12 TM [39.21 h]; OFICIAL [39.21 h]; Excavadora Sobre Oruga 260 HP [39.21 h]; CARGADOR SOBRE LLANTAS DE 200-250 HP [19.53 h] |
| 1.07.454 |  | CONFORMACIÓN DE CUERPO DE DIQUE CON MATERIAL PROPIO (A2-I-02) | 55.5d | 2024-04-09 | 2024-06-13 | 1.07.392 FS+0.5d | 0d |  | Camión Cisterna 4x2 400 HP Agua (5000 gal) [500.45 h]; CAPATAZ [1004.66 h]; Motoniveladora 185 HP [1004.66 h]; OPERARIO [1004.66 h]; PEON [4014.87 h]; Rodillo Vib. Liso Autopropulsado 135 HP 12 TM [1004.66 h]; OFICIAL [1004.66 h]; Excavadora Sobre Oruga 260 HP [1004.66 h]; CARGADOR SOBRE LLANTAS DE 200-250 HP [500.45 h] |
| 1.07.457 |  | CONFORMACIÓN DE CUERPO DE DIQUE CON MATERIAL PROPIO INTERFERENCIA SEDACHIMBOTE | 9.5d | 2024-04-11 | 2024-04-22 | 1.07.970 FS+0.5d | 211.05d | 0d | CAPATAZ [30.04 h]; PEON [300.43 h]; Tractor S/Orugas (D6T) - 180 HP [300.43 h]; Excavadora Sobre Oruga 260 HP [300.43 h] |
| 1.07.458 |  | CONFORMACIÓN DE CUERPO DE DIQUE CON MATERIAL PROPIO INTERFERENCIA QUAVI | 6.5d | 2024-04-25 | 2024-05-03 | 1.07.980 FS+0.5d | 220.05d | 0d | CAPATAZ [223.6 h]; PEON [2235.97 h]; Tractor S/Orugas (D6T) - 180 HP [2235.97 h]; Excavadora Sobre Oruga 260 HP [2235.97 h] |
| 1.07.461 |  | CONFORMACIÓN DE CUERPO DE RAMPA CON MATERIAL PROPIO | 2.5d | 2024-05-02 | 2024-05-04 | 1.07.800 FS+0.5d | 236.05d | 0d | Camión Cisterna 4x2 400 HP Agua (5000 gal) [20.6 h]; CAPATAZ [41.36 h]; Motoniveladora 185 HP [41.36 h]; OPERARIO [41.36 h]; PEON [165.28 h]; Rodillo Vib. Liso Autopropulsado 135 HP 12 TM [41.36 h]; OFICIAL [41.36 h]; Excavadora Sobre Oruga 260 HP [41.36 h]; CARGADOR SOBRE LLANTAS DE 200-250 HP [20.6 h] |
| 1.07.459 |  | CONFORMACIÓN DE CUERPO DE DIQUE CON MATERIAL PROPIO LIBERACIÓN PREDIAL LI | 2.5d | 2024-05-04 | 2024-05-07 | 1.07.990 FS+0.5d | 206.05d | 0d | CAPATAZ [30.04 h]; PEON [300.43 h]; Tractor S/Orugas (D6T) - 180 HP [300.43 h]; Excavadora Sobre Oruga 260 HP [300.43 h] |
| 1.07.455 |  | CONFORMACIÓN DE CUERPO DE DIQUE CON MATERIAL PROPIO (A2-D-01) | 41.5d | 2024-06-18 | 2024-08-07 | 1.07.393 FS+0.5d | 23.05d | 0d | Camión Cisterna 4x2 400 HP Agua (5000 gal) [546.1 h]; CAPATAZ [1096.3 h]; Motoniveladora 185 HP [1096.3 h]; OPERARIO [1096.3 h]; PEON [4381.09 h]; Rodillo Vib. Liso Autopropulsado 135 HP 12 TM [1096.3 h]; OFICIAL [1096.3 h]; Excavadora Sobre Oruga 260 HP [1096.3 h]; CARGADOR SOBRE LLANTAS DE 200-250 HP [546.1 h] |
| 1.07.460 |  | CONFORMACIÓN DE CUERPO DE DIQUE CON MATERIAL PROPIO LIBERACIÓN PREDIAL LD | 22.5d | 2024-07-04 | 2024-08-01 | 1.07.991 FS+0.5d | 70.55d | 0d | CAPATAZ [30.04 h]; PEON [300.43 h]; Tractor S/Orugas (D6T) - 180 HP [300.43 h]; Excavadora Sobre Oruga 260 HP [300.43 h] |
|  | 7 | **CONFORMACIÓN DE RELLENO NO ESTRUCTURAL CON MATERIAL PROPIO** |  | 2024-01-15 | 2024-08-12 |  |  |  |  |
| 1.07.491 |  | CONFORMACIÓN DE RELLENO NO ESTRUCTURAL CON MATERIAL PROPIO (A2-I-01) | 1.5d | 2024-01-15 | 2024-01-16 | 1.07.451 FS+0.5d | 314.05d | 0d | Camión Cisterna 4x2 400 HP Agua (5000 gal) [24.84 h]; CAPATAZ [12.42 h]; OPERARIO [24.84 h]; PEON [50.25 h]; Rodillo Vib. Liso Autopropulsado 135 HP 12 TM [24.84 h]; Tractor S/Orugas (D6T) - 180 HP [24.84 h] |
| 1.07.494 |  | CONFORMACIÓN DE RELLENO NO ESTRUCTURAL CON MATERIAL PROPIO INTERFERENCIA SEDACHIMBOTE | 0.5d | 2024-04-23 | 2024-04-23 | 1.07.457 FS+0.5d | 211.05d | 0d | CAPATAZ [30.04 h]; PEON [300.43 h]; Tractor S/Orugas (D6T) - 180 HP [300.43 h]; Excavadora Sobre Oruga 260 HP [300.43 h] |
| 1.07.495 |  | CONFORMACIÓN DE RELLENO NO ESTRUCTURAL CON MATERIAL PROPIO INTERFERENCIA QUAVI | 0.5d | 2024-05-04 | 2024-05-04 | 1.07.458 FS+0.5d | 220.05d | 0d | CAPATAZ [223.6 h]; PEON [2235.97 h]; Tractor S/Orugas (D6T) - 180 HP [2235.97 h]; Excavadora Sobre Oruga 260 HP [2235.97 h] |
| 1.07.496 |  | CONFORMACIÓN DE RELLENO NO ESTRUCTURAL CON MATERIAL PROPIO LIBERACIÓN PREDIAL LI | 0.5d | 2024-05-08 | 2024-05-08 | 1.07.459 FS+0.5d | 206.05d | 0d | CAPATAZ [30.04 h]; PEON [300.43 h]; Tractor S/Orugas (D6T) - 180 HP [300.43 h]; Excavadora Sobre Oruga 260 HP [300.43 h] |
| 1.07.492 |  | CONFORMACIÓN DE RELLENO NO ESTRUCTURAL CON MATERIAL PROPIO (A2-I-02) | 1.5d | 2024-06-14 | 2024-06-15 | 1.07.454 FS+0.5d | 0d |  | Camión Cisterna 4x2 400 HP Agua (5000 gal) [24.12 h]; CAPATAZ [12.06 h]; OPERARIO [24.12 h]; PEON [48.8 h]; Rodillo Vib. Liso Autopropulsado 135 HP 12 TM [24.12 h]; Tractor S/Orugas (D6T) - 180 HP [24.12 h] |
| 1.07.497 |  | CONFORMACIÓN DE RELLENO NO ESTRUCTURAL CON MATERIAL PROPIO LIBERACIÓN PREDIAL LD | 1.5d | 2024-08-01 | 2024-08-03 | 1.07.460 FS+0.5d | 70.55d | 0d | CAPATAZ [30.04 h]; PEON [300.43 h]; Tractor S/Orugas (D6T) - 180 HP [300.43 h]; Excavadora Sobre Oruga 260 HP [300.43 h] |
| 1.07.493 |  | CONFORMACIÓN DE RELLENO NO ESTRUCTURAL CON MATERIAL PROPIO (A2-D-01) | 3.5d | 2024-08-08 | 2024-08-12 | 1.07.455 FS+0.5d | 23.05d | 0d | Camión Cisterna 4x2 400 HP Agua (5000 gal) [101.98 h]; CAPATAZ [50.99 h]; OPERARIO [101.98 h]; PEON [206.28 h]; Rodillo Vib. Liso Autopropulsado 135 HP 12 TM [101.98 h]; Tractor S/Orugas (D6T) - 180 HP [101.98 h] |
|  | 8 | **CONFORMACIÓN DE MATERIAL GRANULAR EN CORONA DE DIQUE** |  | 2023-12-19 | 2025-01-16 |  |  |  |  |
| 1.07.552 |  | CONFORMACIÓN DE MATERIAL GRANULAR EN CORONA DE DIQUE (A2-I-01-B) | 1.5d | 2023-12-19 | 2023-12-20 | 1.07.682 FS+0.5d | 350.02d | 0d | Camión Cisterna 4x2 400 HP Agua (5000 gal) [5.85 h]; CAPATAZ [11.7 h]; Motoniveladora 185 HP [11.7 h]; OPERARIO [11.7 h]; PEON [46.77 h]; Rodillo Vib. Liso Autopropulsado 135 HP 12 TM [11.7 h]; OFICIAL [11.7 h]; Excavadora Sobre Oruga 260 HP [11.7 h]; CARGADOR SOBRE LLANTAS DE 200-250 HP [5.85 h] |
| 1.07.553 |  | CONFORMACIÓN DE MATERIAL GRANULAR EN CORONA DE DIQUE (A2-I-03) | 2.5d | 2024-01-19 | 2024-01-22 | 1.07.683 FS+0.5d | 324.05d | 0d | Camión Cisterna 4x2 400 HP Agua (5000 gal) [24.15 h]; CAPATAZ [48.3 h]; Motoniveladora 185 HP [48.3 h]; OPERARIO [48.3 h]; PEON [193.02 h]; Rodillo Vib. Liso Autopropulsado 135 HP 12 TM [48.3 h]; OFICIAL [48.3 h]; Excavadora Sobre Oruga 260 HP [48.3 h]; CARGADOR SOBRE LLANTAS DE 200-250 HP [24.15 h] |
| 1.07.551 |  | CONFORMACIÓN DE MATERIAL GRANULAR EN CORONA DE DIQUE (A2-I-01) | 2.5d | 2024-02-01 | 2024-02-03 | 1.07.681 FS+0.5d | 314.05d |  | Camión Cisterna 4x2 400 HP Agua (5000 gal) [13.34 h]; CAPATAZ [26.68 h]; Motoniveladora 185 HP [26.68 h]; OPERARIO [26.68 h]; PEON [106.61 h]; Rodillo Vib. Liso Autopropulsado 135 HP 12 TM [26.68 h]; OFICIAL [26.68 h]; Excavadora Sobre Oruga 260 HP [26.68 h]; CARGADOR SOBRE LLANTAS DE 200-250 HP [13.34 h] |
| 1.07.556 |  | CONFORMACIÓN DE MATERIAL GRANULAR EN CORONA DE DIQUE (A2-D-02) | 2.5d | 2024-04-01 | 2024-04-03 | 1.07.686 FS+0.5d | 264.05d | 0d | Camión Cisterna 4x2 400 HP Agua (5000 gal) [24.81 h]; CAPATAZ [49.62 h]; Motoniveladora 185 HP [49.62 h]; OPERARIO [49.62 h]; PEON [198.3 h]; Rodillo Vib. Liso Autopropulsado 135 HP 12 TM [49.62 h]; OFICIAL [49.62 h]; Excavadora Sobre Oruga 260 HP [49.62 h]; CARGADOR SOBRE LLANTAS DE 200-250 HP [24.81 h] |
| 1.07.561 |  | CONFORMACIÓN DE CORONA DE RAMPA | 2.5d | 2024-05-06 | 2024-05-08 | 1.07.461 FS+0.5d | 236.05d |  | Camión Cisterna 4x2 400 HP Agua (5000 gal) [11.42 h]; CAPATAZ [22.84 h]; Motoniveladora 185 HP [22.84 h]; OPERARIO [22.84 h]; PEON [91.27 h]; Rodillo Vib. Liso Autopropulsado 135 HP 12 TM [22.84 h]; OFICIAL [22.84 h]; Excavadora Sobre Oruga 260 HP [22.84 h]; CARGADOR SOBRE LLANTAS DE 200-250 HP [11.42 h] |
| 1.07.558 |  | CONFORMACIÓN DE MATERIAL GRANULAR EN CORONA DE DIQUE INTERFERENCIA QUAVI | 2.5d | 2024-05-23 | 2024-05-25 | 1.07.688 FS+0.5d | 220.05d | 0d | CAPATAZ [223.6 h]; PEON [2235.97 h]; Tractor S/Orugas (D6T) - 180 HP [2235.97 h]; Excavadora Sobre Oruga 260 HP [2235.97 h] |
| 1.07.557 |  | CONFORMACIÓN DE MATERIAL GRANULAR EN CORONA DE DIQUE INTERFERENCIA SEDACHIMBOTE | 4.5d | 2024-05-31 | 2024-06-05 | 1.07.687 FS+0.5d | 211.05d | 0d | CAPATAZ [30.04 h]; PEON [300.43 h]; Tractor S/Orugas (D6T) - 180 HP [300.43 h]; Excavadora Sobre Oruga 260 HP [300.43 h] |
| 1.07.559 |  | CONFORMACIÓN DE MATERIAL GRANULAR EN CORONA DE DIQUE LIBERACIÓN PREDIAL LI | 3.5d | 2024-06-06 | 2024-06-10 | 1.07.689 FS+0.5d | 206.05d | 0d | CAPATAZ [30.04 h]; PEON [300.43 h]; Tractor S/Orugas (D6T) - 180 HP [300.43 h]; Excavadora Sobre Oruga 260 HP [300.43 h] |
| 1.07.560 |  | CONFORMACIÓN DE MATERIAL GRANULAR EN CORONA DE DIQUE LIBERACIÓN PREDIAL LD | 12.5d | 2024-11-04 | 2024-11-19 | 1.07.690 FS+0.5d | 70.55d | 0d | CAPATAZ [30.04 h]; PEON [300.43 h]; Tractor S/Orugas (D6T) - 180 HP [300.43 h]; Excavadora Sobre Oruga 260 HP [300.43 h] |
| 1.07.554 |  | CONFORMACIÓN DE MATERIAL GRANULAR EN CORONA DE DIQUE (A2-I-02) | 30.5d | 2024-12-10 | 2025-01-16 | 1.07.684 FS+0.5d | 0d |  | Camión Cisterna 4x2 400 HP Agua (5000 gal) [134.99 h]; CAPATAZ [269.97 h]; Motoniveladora 185 HP [269.97 h]; OPERARIO [269.97 h]; PEON [1078.94 h]; Rodillo Vib. Liso Autopropulsado 135 HP 12 TM [269.97 h]; OFICIAL [269.97 h]; Excavadora Sobre Oruga 260 HP [269.97 h]; CARGADOR SOBRE LLANTAS DE 200-250 HP [134.99 h] |
| 1.07.555 |  | CONFORMACIÓN DE MATERIAL GRANULAR EN CORONA DE DIQUE (A2-D-01) | 17.5d | 2024-12-24 | 2025-01-15 | 1.07.685 FS+0.5d | 23.05d | 0d | Camión Cisterna 4x2 400 HP Agua (5000 gal) [114.36 h]; CAPATAZ [228.72 h]; Motoniveladora 185 HP [228.72 h]; OPERARIO [229 h]; PEON [914 h]; Rodillo Vib. Liso Autopropulsado 135 HP 12 TM [229 h]; OFICIAL [229 h]; Excavadora Sobre Oruga 260 HP [228.72 h]; CARGADOR SOBRE LLANTAS DE 200-250 HP [114.36 h] |

| ID | WBS | Activity | Duration | Start | Finish | Predecessors | Total float | Free float | Resources |
| --- | --- | --- | --- | --- | --- | --- | --- | --- | --- |
|  | 9 | **GEOTEXTIL NO TEJIDO 400 G/M2, INC. COLOCACIÓN** |  | 2023-12-07 | 2024-09-12 |  |  |  |  |
| 1.07.622 |  | GEOTEXTIL NO TEJIDO 400 G/M2, INC. COLOCACIÓN (A2-I-01-B) | 1.5d | 2023-12-07 | 2023-12-11 | 1.07.292 FS+0.5d | 45.55d | 0d | CAPATAZ [1.64 h]; OPERARIO [16.43 h]; PEON [65.7 h] |
| 1.07.623 |  | GEOTEXTIL NO TEJIDO 400 G/M2, INC. COLOCACIÓN (A2-I-03) | 1.5d | 2024-01-05 | 2024-01-06 | 1.07.293 FS+0.5d | 324.05d | 0d | CAPATAZ [7.13 h]; OPERARIO [71.25 h]; PEON [285 h] |
| 1.07.621 |  | GEOTEXTIL NO TEJIDO 400 G/M2, INC. COLOCACIÓN (A2-I-01) | 1.5d | 2024-01-20 | 2024-01-22 | 1.07.291 FS+0.5d | 314.05d | 0d | CAPATAZ [2.76 h]; OPERARIO [27.58 h]; PEON [110.34 h] |
| 1.07.626 |  | GEOTEXTIL NO TEJIDO 400 G/M2, INC. COLOCACIÓN (A2-D-02) | 1.5d | 2024-03-18 | 2024-03-19 | 1.07.296 FS+0.5d | 264.05d | 0d | CAPATAZ [7.28 h]; OPERARIO [72.77 h]; PEON [291.07 h] |
| 1.07.627 |  | GEOTEXTIL NO TEJIDO 400 G/M2, INC. COLOCACIÓN INTERFERENCIA SEDACHIMBOTE | 3.5d | 2024-05-02 | 2024-05-06 | 1.07.850 FS+0.5d | 211.05d | 0d | CAPATAZ [30.04 h]; PEON [300.43 h]; Tractor S/Orugas (D6T) - 180 HP [300.43 h]; Excavadora Sobre Oruga 260 HP [300.43 h] |
| 1.07.628 |  | GEOTEXTIL NO TEJIDO 400 G/M2, INC. COLOCACIÓN INTERFERENCIA QUAVI | 1.5d | 2024-05-09 | 2024-05-10 | 1.07.860 FS+0.5d | 220.05d | 0d | CAPATAZ [223.6 h]; PEON [2235.97 h]; Tractor S/Orugas (D6T) - 180 HP [2235.97 h]; Excavadora Sobre Oruga 260 HP [2235.97 h] |
| 1.07.629 |  | GEOTEXTIL NO TEJIDO 400 G/M2, INC. COLOCACIÓN LIBERACIÓN PREDIAL LI | 2.5d | 2024-05-16 | 2024-05-18 | 1.07.870 FS+0.5d | 206.05d | 0d | CAPATAZ [30.04 h]; PEON [300.43 h]; Tractor S/Orugas (D6T) - 180 HP [300.43 h]; Excavadora Sobre Oruga 260 HP [300.43 h] |
| 1.07.624 |  | GEOTEXTIL NO TEJIDO 400 G/M2, INC. COLOCACIÓN (A2-I-02) | 18.5d | 2024-07-04 | 2024-07-25 | 1.07.294 FS+0.5d | 0d |  | CAPATAZ [32.38 h]; OPERARIO [323.78 h]; PEON [1295.12 h] |
| 1.07.630 |  | GEOTEXTIL NO TEJIDO 400 G/M2, INC. COLOCACIÓN LIBERACIÓN PREDIAL LD | 9.5d | 2024-08-14 | 2024-08-26 | 1.07.880 FS+0.5d | 70.55d | 0d | CAPATAZ [30.04 h]; PEON [300.43 h]; Tractor S/Orugas (D6T) - 180 HP [300.43 h]; Excavadora Sobre Oruga 260 HP [300.43 h] |
| 1.07.625 |  | GEOTEXTIL NO TEJIDO 400 G/M2, INC. COLOCACIÓN (A2-D-01) | 13.5d | 2024-08-27 | 2024-09-12 | 1.07.295 FS+0.5d | 23.05d | 0d | CAPATAZ [36.74 h]; OPERARIO [367.43 h]; PEON [1469.71 h] |
|  | 12 | **COLOCACION Y ACOMODO DE ROCA EN TALUD DE DIQUE** |  | 2023-12-16 | 2024-12-23 |  |  |  |  |
| 1.07.682 |  | COLOCACION Y ACOMODO DE ROCA EN TALUD DE DIQUE (A2-I-01-B) | 1.5d | 2023-12-16 | 2023-12-18 | 1.03.612 FS+0.5d | 350.02d | 0d | CAPATAZ [62.77 h]; PEON [376.43 h]; Excavadora Sobre Oruga 260 HP [94.11 h]; OPERARIO [62.77 h] |
| 1.07.683 |  | COLOCACION Y ACOMODO DE ROCA EN TALUD DE DIQUE (A2-I-03) | 5.5d | 2024-01-12 | 2024-01-18 | 1.03.613 FS+0.5d | 324.05d | 0d | CAPATAZ [407.94 h]; PEON [2446.41 h]; Excavadora Sobre Oruga 260 HP [611.6 h]; OPERARIO [407.94 h] |
| 1.07.681 |  | COLOCACION Y ACOMODO DE ROCA EN TALUD DE DIQUE (A2-I-01) | 2.5d | 2024-01-29 | 2024-01-31 | 1.03.611 FS+0.5d | 314.05d | 0d | CAPATAZ [106.07 h]; PEON [636.12 h]; Excavadora Sobre Oruga 260 HP [159.03 h]; OPERARIO [106.07 h] |
| 1.07.686 |  | COLOCACION Y ACOMODO DE ROCA EN TALUD DE DIQUE (A2-D-02) | 4.5d | 2024-03-23 | 2024-03-30 | 1.03.617 FS+0.5d | 264.05d | 0d | CAPATAZ [415.12 h]; PEON [2489.49 h]; Excavadora Sobre Oruga 260 HP [622.37 h]; OPERARIO [415.12 h] |
| 1.07.688 |  | COLOCACION Y ACOMODO DE ROCA EN TALUD DE DIQUE INTERFERENCIA QUAVI | 3.5d | 2024-05-18 | 2024-05-22 | 1.03.619 FS+0.5d | 220.05d | 0d | CAPATAZ [223.6 h]; PEON [2235.97 h]; Tractor S/Orugas (D6T) - 180 HP [2235.97 h]; Excavadora Sobre Oruga 260 HP [2235.97 h] |
| 1.07.687 |  | COLOCACION Y ACOMODO DE ROCA EN TALUD DE DIQUE INTERFERENCIA SEDACHIMBOTE | 8.5d | 2024-05-21 | 2024-05-30 | 1.03.618 FS+0.5d | 211.05d | 0d | CAPATAZ [30.04 h]; PEON [300.43 h]; Tractor S/Orugas (D6T) - 180 HP [300.43 h]; Excavadora Sobre Oruga 260 HP [300.43 h] |
| 1.07.689 |  | COLOCACION Y ACOMODO DE ROCA EN TALUD DE DIQUE LIBERACIÓN PREDIAL LI | 8.5d | 2024-05-27 | 2024-06-05 | 1.03.620 FS+0.5d | 206.05d | 0d | CAPATAZ [30.04 h]; PEON [300.43 h]; Tractor S/Orugas (D6T) - 180 HP [300.43 h]; Excavadora Sobre Oruga 260 HP [300.43 h] |
| 1.07.690 |  | COLOCACION Y ACOMODO DE ROCA EN TALUD DE DIQUE LIBERACIÓN PREDIAL LD | 26.5d | 2024-10-01 | 2024-11-04 | 1.03.621 FS+0.5d | 70.55d | 0d | CAPATAZ [30.04 h]; PEON [300.43 h]; Tractor S/Orugas (D6T) - 180 HP [300.43 h]; Excavadora Sobre Oruga 260 HP [300.43 h] |
| 1.07.684 |  | COLOCACION Y ACOMODO DE ROCA EN TALUD DE DIQUE (A2-I-02) | 48.5d | 2024-10-12 | 2024-12-09 | 1.03.614 FS+0.5d | 0d |  | CAPATAZ [1745.18 h]; PEON [10465.9 h]; Excavadora Sobre Oruga 260 HP [2616.47 h]; OPERARIO [1745.18 h] |
| 1.07.685 |  | COLOCACION Y ACOMODO DE ROCA EN TALUD DE DIQUE (A2-D-01) | 35.5d | 2024-11-12 | 2024-12-23 | 1.03.616 FS+0.5d | 23.05d | 0d | CAPATAZ [1908.95 h]; PEON [11448 h]; Excavadora Sobre Oruga 260 HP [2862 h]; OPERARIO [1908.95 h] |
|  | 4 | **OBRAS DE ARTE** |  | 2024-08-28 | 2024-10-29 |  |  |  |  |
|  | 1 | **TOMAS O CAPTACIONES** |  | 2024-08-28 | 2024-10-01 |  |  |  |  |
|  | 1 | **MOVIMIENTO DE TIERRAS** |  | 2024-08-28 | 2024-10-01 |  |  |  |  |
| 1.08.01 |  | EXCAVACION ESTRUCTURAL PARA OBRAS DE ARTE | 14.5d | 2024-08-28 | 2024-09-14 | 1.07.180 FS+83.5d | 8.81d | 0d | CAPATAZ [6.42 h]; PEON [64.23 h]; Tractor S/Orugas (D6T) - 180 HP [64 h]; Excavadora Sobre Oruga 260 HP [64.23 h] |
| 1.08.02 |  | RELLENO ESTRUCTURAL PARA OBRAS DE ARTE CON MATERIAL PROPIO | 13.5d | 2024-09-16 | 2024-10-01 | 1.08.01 FS+0.5d | 8.81d | 0d | Camión Cisterna 4x2 400 HP Agua (5000 gal) [335 h]; CAPATAZ [168 h]; OPERARIO [335 h]; PEON [678 h]; Rodillo Vib. Liso Autopropulsado 135 HP 12 TM [335 h]; Tractor S/Orugas (D6T) - 180 HP [335 h] |

| ID | WBS | Activity | Duration | Start | Finish | Predecessors | Total float | Free float | Resources |
| --- | --- | --- | --- | --- | --- | --- | --- | --- | --- |
|  | 2 | **CANALES** |  | 2024-09-16 | 2024-10-11 |  |  |  |  |
|  | 1 | **MOVIMIENTO DE TIERRAS** |  | 2024-09-16 | 2024-10-11 |  |  |  |  |
| 1.08.03 |  | EXCAVACION ESTRUCTURAL PARA OBRAS DE ARTE | 7.5d | 2024-09-16 | 2024-09-24 | 1.08.01 FS+0.53d | 47.83d | 0d | CAPATAZ [6.42 h]; PEON [64.23 h]; Tractor S/Orugas (D6T) - 180 HP [64 h]; Excavadora Sobre Oruga 260 HP [64.23 h] |
| 1.08.04 |  | RELLENO ESTRUCTURAL PARA OBRAS DE ARTE CON MATERIAL PROPIO | 7.5d | 2024-10-02 | 2024-10-11 | 1.08.02 FS+0.5d | 72.99d | 0d | Camión Cisterna 4x2 400 HP Agua (5000 gal) [335 h]; CAPATAZ [168 h]; OPERARIO [335 h]; PEON [678 h]; Rodillo Vib. Liso Autopropulsado 135 HP 12 TM [335 h]; Tractor S/Orugas (D6T) - 180 HP [335 h] |
|  | 3 | **OBRAS DE DESCARGA** |  | 2024-09-25 | 2024-09-26 |  |  |  |  |
|  | 1 | **MOVIMIENTO DE TIERRAS** |  | 2024-09-25 | 2024-09-26 |  |  |  |  |
| 1.08.05 |  | EXCAVACION ESTRUCTURAL PARA OBRAS DE ARTE | 1.5d | 2024-09-25 | 2024-09-26 | 1.08.03 FS+0.5d | 47.83d | 0d | CAPATAZ [6.42 h]; PEON [64.23 h]; Tractor S/Orugas (D6T) - 180 HP [64 h]; Excavadora Sobre Oruga 260 HP [64.23 h] |
|  | 4 | **RETORNOS TIPO A2-OA-RE-I-11-25** |  | 2024-09-27 | 2024-10-16 |  |  |  |  |
|  | 1 | **MOVIMIENTO DE TIERRAS** |  | 2024-09-27 | 2024-10-16 |  |  |  |  |
| 1.08.07 |  | EXCAVACION ESTRUCTURAL PARA OBRAS DE ARTE | 1.5d | 2024-09-27 | 2024-09-28 | 1.08.05 FS+0.5d | 47.83d | 0d | CAPATAZ [6.42 h]; PEON [64.23 h]; Tractor S/Orugas (D6T) - 180 HP [64 h]; Excavadora Sobre Oruga 260 HP [64.23 h] |
| 1.08.08 |  | RELLENO ESTRUCTURAL PARA OBRAS DE ARTE CON MATERIAL PROPIO | 3.76d | 2024-10-12 | 2024-10-16 | 1.08.04 FS+0.5d | 76.78d | 0d | Camión Cisterna 4x2 400 HP Agua (5000 gal) [335 h]; CAPATAZ [168 h]; OPERARIO [335 h]; PEON [678 h]; Rodillo Vib. Liso Autopropulsado 135 HP 12 TM [335 h]; Tractor S/Orugas (D6T) - 180 HP [335 h] |
|  | 5 | **RETORNOS Q=100 A 1000 l/s** |  | 2024-09-30 | 2024-10-29 |  |  |  |  |
|  | 1 | **MOVIMIENTO DE TIERRAS** |  | 2024-09-30 | 2024-10-29 |  |  |  |  |
| 1.08.09 |  | EXCAVACIÓN ESTRUCTURAL PARA OBRAS DE ARTE | 9.5d | 2024-09-30 | 2024-10-11 | 1.08.07 FS+0.5d | 47.83d | 0d | CAPATAZ [6.42 h]; PEON [64.23 h]; Tractor S/Orugas (D6T) - 180 HP [64 h]; Excavadora Sobre Oruga 260 HP [64.23 h] |
| 1.08.10 |  | CAMA DE ARENA | 1.5d | 2024-10-12 | 2024-10-14 | 1.08.09 FS+0.5d | 51.33d | 0d | CAPATAZ [5.24 h]; PEON [41.96 h] |
| 1.08.11 |  | RELLENO ESTRUCTURAL PARA OBRAS DE ARTE CON MATERIAL PROPIO | 14.5d | 2024-10-12 | 2024-10-29 | 1.08.09 FS+0.5d | 47.83d | 0d | Camión Cisterna 4x2 400 HP Agua (5000 gal) [335 h]; CAPATAZ [168 h]; OPERARIO [335 h]; PEON [678 h]; Rodillo Vib. Liso Autopropulsado 135 HP 12 TM [335 h]; Tractor S/Orugas (D6T) - 180 HP [335 h] |
|  | 6 | **INTERFERENCIAS** |  | 2024-09-17 | 2024-10-26 |  |  |  |  |
|  | 3 | **REPOSICION DE ESTRUCTURAS (PASE DE AGUA)** |  | 2024-10-12 | 2024-10-18 |  |  |  |  |
| 1.09.01 |  | DEMOLICIÓN DE ESTRUCTURAS EXISTENTES | 0.53d | 2024-10-12 | 2024-10-12 | 1.08.09 FS+0.53d | 81.66d | 0d | CAPATAZ; OPERARIO; PEON; Excavadora + Martillo hidraúlico |
| 1.09.02 |  | REPOSICIÓN DE PASE DE AGUA TUBERÍA HDPE Ø=36" | 0.53d | 2024-10-14 | 2024-10-14 | 1.09.01 FS+0.48d | 93.75d | 0d | CAPATAZ; OPERARIO; PEON; Retroexcavador 58 HP |
| 1.09.03 |  | REPOSICIÓN DE PASE DE AGUA TUBERÍA HDPE Ø=24" | 0.53d | 2024-10-15 | 2024-10-15 | 1.09.02 FS+0.53d | 93.75d | 0d | CAPATAZ [0.05 h]; OPERARIO [1.07 h]; PEON [2.13 h]; Retroexcavador 58 HP [0.53 h] |
| 1.09.05 |  | SUMINISTRO Y MONTAJE DE PANELES DE C°A° 1.9mx1.0mx0.20m EN PASE DE AGUA | 0.53d | 2024-10-16 | 2024-10-16 | 1.09.03 FS+0.5d | 93.75d | 0d | CAPATAZ [0.12 h]; PEON [2.4 h] |
| 1.09.06 |  | SUMINISTRO Y MONTAJE DE PANELES DE C°A° 1.6mx1.0mx0.20m EN PASE DE AGUA | 0.53d | 2024-10-17 | 2024-10-17 | 1.09.05 SS+1.06d | 93.75d | 0d | CAPATAZ [0.6 h]; PEON [12 h] |
| 1.09.07 |  | SUMINISTRO Y MONTAJE DE PANELES DE C°A° 1.8mx1.0mx0.20m EN PASE DE AGUA | 0.53d | 2024-10-18 | 2024-10-18 | 1.09.06 FS+0.53d | 93.75d | 0d | CAPATAZ [0.64 h]; PEON [12.8 h] |

| ID | WBS | Activity | Duration | Start | Finish | Predecessors | Total float | Free float | Resources |
| --- | --- | --- | --- | --- | --- | --- | --- | --- | --- |
|  | 4 | **CABEZAL DE ENTRADA Y SALIDA (PASE DE AGUA)** |  | 2024-10-19 | 2024-10-25 |  |  |  |  |
| 1.09.10 |  | ENCOFRADO Y DESENCOFRADO NORMAL | 4.5d | 2024-10-19 | 2024-10-24 | 1.09.07 FS+0.5d | 93.75d | 0d | CAPATAZ [16.27 h]; OPERARIO [32.53 h]; PEON [32.53 h] |
| 1.09.09 |  | CONCRETO 175 Kg/Cm2 | 0.5d | 2024-10-25 | 2024-10-25 | 1.09.10 FS+0.5d | 93.75d |  | CAPATAZ; OPERARIO; PEON; OFICIAL |
|  | 5 | **CRUCE VEHICULAR (PASE DE AGUA)** |  | 2024-09-17 | 2024-10-01 |  |  |  |  |
| 1.09.14 |  | ACERO DE REFUERZO fy=4200 kg/cm2 | 3.5d | 2024-09-17 | 2024-09-20 | 1.08.03 SS+1.2d | 113.64d | 0d | CAPATAZ [2.4 h]; OPERARIO [24.04 h]; PEON [24.04 h] |
| 1.09.13 |  | ENCOFRADO Y DESENCOFRADO NORMAL | 5.5d | 2024-09-21 | 2024-09-27 | 1.09.14 FS+0.5d | 113.64d | 0d | CAPATAZ [23.42 h]; OPERARIO [46.85 h]; PEON [46.85 h] |
| 1.09.11 |  | CONCRETO f'c=280 kg/cm2 | 0.5d | 2024-09-28 | 2024-09-28 | 1.09.13 FS+0.5d | 113.64d | 0d | CAPATAZ [0.08 h]; OPERARIO [1.68 h]; PEON [3.36 h]; OFICIAL [0.84 h] |
| 1.09.12 |  | CONCRETO CICLÓPEO F´C=170 Kg/cm2 | 0.59d | 2024-09-30 | 2024-09-30 | 1.09.11 FS+0.53d | 113.64d | 0d | CAPATAZ; OPERARIO; PEON; OFICIAL |
| 1.09.15 |  | MONTAJE DE LOSA PREFABRICADA | 0.53d | 2024-10-01 | 2024-10-01 | 1.09.12 FS+0.53d | 113.64d |  | CAPATAZ [0.08 h]; OPERARIO [0.8 h]; PEON [3.2 h] |
|  | 6 | **REPOSICION DE CANALES** |  | 2024-10-14 | 2024-10-26 |  |  |  |  |
|  | 1 | **MOVIMIENTO DE TIERRAS** |  | 2024-10-14 | 2024-10-26 |  |  |  |  |
| 1.09.16 |  | DEMOLICION DE ESTRUCTURAS EXISTENTES | 8.5d | 2024-10-14 | 2024-10-23 | 1.09.01 FS+0.5d | 81.66d | 0d | CAPATAZ [6.64 h]; OPERARIO [132.72 h]; PEON [199.09 h]; Excavadora + Martillo hidraúlico [66.37 h] |
| 1.09.17 |  | EXCAVACIÓN EN TERRENO NATURAL CON EQUIPO | 0.53d | 2024-10-24 | 2024-10-24 | 1.09.16 FS+0.53d | 81.66d | 0d | CAPATAZ [3.95 h]; CUADRADOR/VIGÍA [39.47 h]; PEON [78.94 h]; Retroexcavador 58 HP [39.47 h] |
| 1.09.18 |  | RELLENO ESTRUCTURAL PARA OBRAS DE ARTE CON MATERIAL PROPIO | 1.06d | 2024-10-25 | 2024-10-26 | 1.09.17 FS+0.53d | 93.31d |  | CAPATAZ [1.31 h]; CUADRADOR/VIGÍA [13.05 h]; PEON [26.1 h]; Rodillo Vib. Liso Autopropulsado 135 HP 12 TM [13.05 h]; Retroexcavador 58 HP [3.26 h] |
|  | 5 | **TRANSPORTE DE MATERIAL** |  | 2023-11-28 | 2025-01-16 |  |  |  |  |
| 1.09.21 |  | TRANSPORTE DE MATERIAL EXCEDENTE | 276.59d | 2023-11-28 | 2024-10-28 | 1.07.100 SS | 90.96d | 0.06d | Camión Volquete (15 m3); CAPATAZ; CUADRADOR/VIGÍA; Excavadora Sobre Oruga 260 HP |
| 1.09.20 |  | TRANSPORTE DE ROCA | 314d | 2023-12-11 | 2024-12-23 | 1.03.612 SS-1d, 1.07.685 FF | 45.05d |  | Camión Volquete (15 m3); CAPATAZ; CUADRADOR/VIGÍA; Excavadora Sobre Oruga 260 HP |
| 1.09.19 |  | TRANSPORTE DE MATERIAL GRANULAR | 331.5d | 2023-12-13 | 2025-01-16 | 1.07.361 SS+0.2d, 1.07.554 FF | 25.81d |  | CAPATAZ; Excavadora Sobre Oruga 260 HP; CUADRADOR/VIGÍA; Camión Volquete (15 m3) |
|  | 7 | **ARQUITECTURA Y PAISAJISMO** |  | 2024-10-25 | 2024-11-09 |  |  |  |  |
|  | 1 | **MOVIMIENTO DE TIERRAS** |  | 2024-10-25 | 2024-10-29 |  |  |  |  |
| 1.09.22 |  | EXCAVACIÓN MANUAL PARA INSTALACIÓN DE BORDILLOS Y CIMENTACIONES | 1.5d | 2024-10-25 | 2024-10-26 | 1.09.17 FS+0.5d | 81.66d | 0d | PEON [11.39 h]; CAPATAZ [1.14 h] |
| 1.09.23 |  | EXCAVACIÓN PARA MEJORAMIENTO DE SUELO CON TIERRA VEGETAL | 0.5d | 2024-10-28 | 2024-10-28 | 1.09.22 FS+0.5d, 1.09.21 FF | 90.9d | 0d | CAPATAZ [0.03 h]; PEON [0.26 h]; Excavadora Sobre Oruga 260 HP [0.26 h]; Tractor S/Orugas (D6T) - 180 HP [0.26 h] |
| 1.09.24 |  | ELIMINACION DE MATERIAL EXCEDENTE (DME´S) | 0.5d | 2024-10-29 | 2024-10-29 | 1.09.23 FS+0.5d | 90.9d |  | CAPATAZ [0.49 h]; OPERARIO [0.98 h]; PEON [5.89 h]; Camión Volquete (15 m3) [2.94 h]; Excavadora Sobre Oruga 260 HP [0.98 h]; Tractor S/Orugas (D6T) - 180 HP [0.98 h] |
|  | 2 | **PAVIMENTOS, RECUBRIMIENTOS Y BORDILLOS** |  | 2024-10-28 | 2024-11-09 |  |  |  |  |
| 1.09.27 |  | BORDILLOS DE PIEDRA DEL LUGAR | 2.65d | 2024-10-28 | 2024-10-30 | 1.09.22 FS+0.53d | 81.66d | 0d | CAPATAZ [1.74 h]; PEON [34.84 h] |
| 1.09.25 |  | PISO DE GRAVILLA | 0.53d | 2024-10-31 | 2024-10-31 | 1.09.27 FS+0.53d | 81.66d | 0d | CAPATAZ [0.24 h]; OPERARIO [2.35 h]; PEON [4.7 h] |
| 1.09.26 |  | RECUBRIMIENTO DE PIEDRA DEL LUGAR e=0.05cm | 6.5d | 2024-11-02 | 2024-11-09 | 1.09.25 FS+0.5d | 81.66d |  | CAPATAZ [5.37 h]; PEON [107.42 h]; OFICIAL [107.42 h] |

| ID | WBS | Activity | Duration | Start | Finish | Predecessors | Total float | Resources |
| --- | --- | --- | --- | --- | --- | --- | --- | --- |
|  | 8 | **PROGRAMA DE CIERRE DE OBRA** |  | 2023-11-28 | 2025-02-15 |  |  |  |
| 01.10.01 |  | ACONDICIONAMIENTO DE DEPÓSITOS DE MATERIALES EXCEDENTES (DME) | 333.5d | 2023-11-28 | 2025-01-06 | A1040 SS-0.4d | 34.67d | Camión Cisterna 4x2 400 HP Agua (5000 gal) [1359.56 h]; CAPATAZ [559.82 h]; OPERARIO [5358.28 h]; Tractor S/Orugas (D6T) - 180 HP [5358.28 h] |
| 01.10.02 |  | RESTAURACIÓN DE ÁREAS DE INSTALACIONES PROVISIONALES | 6.41d | 2025-01-30 | 2025-02-07 | 1.07.234 FS+8d | 0d | CAPATAZ [2.7 h]; PEON [21.3 h]; Camión Cisterna 4x2 400 HP Agua (5000 gal) [5.3 h]; Rodillo Vib. Liso Autopropulsado 135 HP 12 TM [5.3 h] |
| 01.10.03 |  | DESMOVILIZACIÓN DE EQUIPOS | 5.9d | 2025-02-08 | 2025-02-15 | 1.09.26 FF, 1.07.232 FF, 1.07.233 FF, 1.07.235 FF, 1.07.236 FF, 1.07.810 FF, 1.07.820 FF, 1.07.830 FF, 1.07.840 FF, 1.01.03 FF, 1.05.08 FF, 1.04.47 FF, 1.07.561 FF, 01.02.02 FF, 01.10.02 FS+1.5d, 01.10.01 FF, 1.04.03 FF, 1.04.09 FF, 1.04.12 FF, 1.04.29 FF, 1.04.34 FF, 1.04.39 FF, 1.04.41 FF, 1.04.15 FF, 1.05.01, 1.05.02 FF, 1.06.02 FF, 1.06.03 FF, 1.07.01 FF, 1.07.04 FF, 1.07.551 FF, 1.09.09 FF, 1.09.15 FF, 1.09.18 FF, 1.09.19 FF, 1.09.20 FF, 1.09.24 FF | 0d |  |
